# LhARA1- DK

Schedule from MS Project, 2021-08-03 to 2027-04-30.

## Calendars

- Standard: Mon-Fri 08:00-12:00, 13:00-17:00; Sat-Sun off.

## Schedule

| ID | WBS | Task | Type | Duration | Start | Finish | Total slack | Constraint |
| --- | --- | --- | --- | --- | --- | --- | --- | --- |
| 1 | 1 | **LhARA** |  | 1499d? | 2021-08-03 | 2027-04-30 |  |  |
| 2 | 1.1 | **Proposal** |  | 174d? | 2021-08-03 | 2022-04-01 |  |  |
| 3 | 1.1.1 | Launch of proposal preperation | milestone, manual | 0d | 2021-08-03 | 2021-08-03 |  |  |
| 4 | 1.1.2 | Definition of scope of proposal | milestone, manual | 0d | 2021-09-13 | 2021-09-13 |  |  |
| 5 | 1.1.3 | completion of first drafts and management annexes | milestone, manual | 0d | 2021-11-05 | 2021-11-05 |  |  |
| 6 | 1.1.4 | proposal Complete | milestone, manual | 0d | 2021-12-01 | 2021-12-01 |  |  |
| 7 | 1.1.5 | nominal starting date of the project | milestone, manual | 0d | 2022-04-01 | 2022-04-01 |  |  |
| 8 | 1.1.6 | **WP1 Project Management** |  | 173d? | 2021-08-03 | 2022-03-31 |  |  |
| 9 | 1.1.6.1 | **Project plenary meetings** |  | 49d | 2021-09-16 | 2021-11-23 | 0d |  |
| 10 | 1.1.6.1.1 | Project plenary meetings 1 | manual | 1d | 2021-09-16 | 2021-09-16 |  | start no earlier than 2021-09-16 |
| 11 | 1.1.6.1.2 | Project plenary meetings 2 | manual | 1d | 2021-09-28 | 2021-09-28 |  | start no earlier than 2021-09-28 |
| 12 | 1.1.6.1.3 | Project plenary meetings 3 | manual | 1d | 2021-10-12 | 2021-10-12 |  | start no earlier than 2021-10-12 |
| 13 | 1.1.6.1.4 | Project plenary meetings 4 | manual | 1d | 2021-10-26 | 2021-10-26 |  | start no earlier than 2021-10-26 |
| 14 | 1.1.6.1.5 | Project plenary meetings 5 | manual | 1d | 2021-11-09 | 2021-11-09 |  | start no earlier than 2021-11-09 |
| 15 | 1.1.6.1.6 | Project plenary meetings 6 | manual | 1d | 2021-11-23 | 2021-11-23 |  | start no earlier than 2021-11-23 |
| 16 | 1.1.6.2 | **Project Office meetings** |  | 85d | 2021-08-05 | 2021-12-01 |  |  |
| 17 | 1.1.6.2.1 | Project Office meetings 1 | manual | 1d | 2021-08-05 | 2021-08-05 |  | start no earlier than 2021-08-05 |
| 18 | 1.1.6.2.2 | Project Office meetings 2 | manual | 1d | 2021-08-19 | 2021-08-19 |  | start no earlier than 2021-08-19 |
| 19 | 1.1.6.2.3 | Project Office meetings 3 | manual | 1d | 2021-09-02 | 2021-09-02 |  | start no earlier than 2021-09-02 |
| 20 | 1.1.6.2.4 | Project Office meetings 4 | manual | 1d | 2021-09-16 | 2021-09-16 |  | start no earlier than 2021-09-16 |
| 21 | 1.1.6.2.5 | Project Office meetings 5 | manual | 1d | 2021-10-06 | 2021-10-06 |  | start no earlier than 2021-10-06 |
| 22 | 1.1.6.2.6 | Project Office meetings 6 | manual | 1d | 2021-10-20 | 2021-10-20 |  | start no earlier than 2021-10-20 |
| 23 | 1.1.6.2.7 | Project Office meetings 7 | manual | 1d | 2021-11-03 | 2021-11-03 |  | start no earlier than 2021-11-03 |
| 24 | 1.1.6.2.8 | Project Office meetings 8 | manual | 1d | 2021-11-17 | 2021-11-17 |  | start no earlier than 2021-11-17 |
| 25 | 1.1.6.2.9 | Project Office meetings 8 | manual | 1d | 2021-12-01 | 2021-12-01 |  | start no earlier than 2021-12-01 |

| ID | WBS | Task | Type | Duration | Start | Finish | Total slack | Constraint |
| --- | --- | --- | --- | --- | --- | --- | --- | --- |
| 26 | 1.1.6.3 | **Reporting** |  | 87d? | 2021-08-03 | 2021-12-01 |  |  |
| 27 | 1.1.6.3.1 | LhARA Steering Committee | manual | 1d | 2021-08-03 | 2021-08-03 |  |  |
| 28 | 1.1.6.3.2 | LhARA Expert Panel | manual | 1d? | 2021-08-03 | 2021-08-03 |  |  |
| 29 | 1.1.6.4 | **Outreach** |  | 87d? | 2021-08-03 | 2021-12-01 |  |  |
| 30 | 1.1.6.4.1 | Radiobiology | manual | 1d? | 2021-08-03 | 2021-08-03 |  |  |
| 31 | 1.1.6.4.2 | Public Engagement | manual | 1d? | 2021-08-03 | 2021-08-03 |  |  |
| 32 | 1.1.6.5 | **Task management -Proposal** |  | 87d? | 2021-08-03 | 2021-12-01 |  |  |
| 33 | 1.1.6.5.1 | WP2 Source | manual | 1d? | 2021-08-03 | 2021-08-03 |  |  |
| 34 | 1.1.6.5.2 | WP3 Capture | manual | 1d? | 2021-08-03 | 2021-08-03 |  |  |
| 35 | 1.1.6.5.3 | WP4 Ion-acoustic | manual | 1d? | 2021-08-03 | 2021-08-03 |  |  |
| 36 | 1.1.6.5.4 | WP5 Vertical Beamline | manual | 1d? | 2021-08-03 | 2021-08-03 |  |  |
| 37 | 1.1.6.5.5 | WP6 System design | manual | 1d? | 2021-08-03 | 2021-08-03 |  |  |
| 38 | 1.1.6.6 | **Oversight** |  | 65d? | 2021-08-03 | 2021-11-01 |  |  |
| 39 | 1.1.6.6.1 | Oversight committee - STFC | manual | 1d? | 2021-08-03 | 2021-08-03 |  |  |
| 40 | 1.1.6.6.2 | **Steering Group meetings** |  | 134d | 2021-09-27 | 2022-03-31 | 0d |  |
| 41 | 1.1.6.6.2.1 | Steering Group meetings 1 | manual | 1d | 2021-09-27 | 2021-09-27 |  | start no earlier than 2021-09-27 |
| 42 | 1.1.6.6.2.2 | Steering Group meetings 2 | manual | 1d | 2021-11-22 | 2021-11-22 |  | start no earlier than 2021-11-22 |
| 43 | 1.1.6.6.2.3 | Steering Group meetings 3 | manual | 1d | 2022-01-25 | 2022-01-25 |  | start no earlier than 2022-01-25 |
| 44 | 1.1.6.6.2.4 | Steering Group meetings 4 | manual | 1d | 2022-03-31 | 2022-03-31 |  | start no earlier than 2022-03-31 |
| 45 | 1.1.6.6.3 | LhARA Expert Panel | manual | 1d? | 2021-08-03 | 2021-08-03 |  |  |
| 46 | 1.1.7 | **WP2 Source** |  | 87d? | 2021-08-03 | 2021-12-01 |  |  |
| 47 | 1.1.7.1 | WP definition | manual | 1d? | 2021-08-03 | 2021-08-03 |  |  |
| 48 | 1.1.7.2 | **Sub-project plan** |  | 87d? | 2021-08-03 | 2021-12-01 |  |  |
| 49 | 1.1.7.2.1 | Timeline | manual | 1d? | 2021-08-03 | 2021-08-03 |  |  |
| 50 | 1.1.7.2.2 | Staffing | manual | 1d? | 2021-08-03 | 2021-08-03 |  |  |
| 51 | 1.1.7.2.3 | Equipment | manual | 1d? | 2021-08-03 | 2021-08-03 |  |  |
| 52 | 1.1.7.2.4 | Costs | manual | 1d? | 2021-08-03 | 2021-08-03 |  |  |

| ID | WBS | Task | Type | Duration | Start | Finish | Total slack | Constraint |
| --- | --- | --- | --- | --- | --- | --- | --- | --- |
| 53 | 1.1.7.3 | **Reporting** |  | 87d? | 2021-08-03 | 2021-12-01 |  |  |
| 54 | 1.1.7.3.1 | **Meetings with the PO** |  | 81d | 2021-08-05 | 2021-11-25 | 0d |  |
| 55 | 1.1.7.3.1.1 | Meetings with the PO 1 | manual | 1d | 2021-08-05 | 2021-08-05 |  | start no earlier than 2021-08-05 |
| 56 | 1.1.7.3.1.2 | Meetings with the PO 2 | manual | 1d | 2021-08-19 | 2021-08-19 |  | start no earlier than 2021-08-19 |
| 57 | 1.1.7.3.1.3 | Meetings with the PO 3 | manual | 1d | 2021-09-02 | 2021-09-02 |  | start no earlier than 2021-09-02 |
| 58 | 1.1.7.3.1.4 | Meetings with the PO 4 | manual | 1d | 2021-09-16 | 2021-09-16 |  | start no earlier than 2021-09-16 |
| 59 | 1.1.7.3.1.5 | Meetings with the PO 5 | manual | 1d | 2021-09-30 | 2021-09-30 |  | start no earlier than 2021-09-30 |
| 60 | 1.1.7.3.1.6 | Meetings with the PO 6 | manual | 1d | 2021-10-14 | 2021-10-14 |  | start no earlier than 2021-10-14 |
| 61 | 1.1.7.3.1.7 | Meetings with the PO 7 | manual | 1d | 2021-10-28 | 2021-10-28 |  | start no earlier than 2021-10-28 |
| 62 | 1.1.7.3.1.8 | Meetings with the PO 8 | manual | 1d | 2021-11-11 | 2021-11-11 |  | start no earlier than 2021-11-11 |
| 63 | 1.1.7.3.1.9 | Meetings with the PO 9 | manual | 1d | 2021-11-25 | 2021-11-25 |  | start no earlier than 2021-11-25 |
| 64 | 1.1.7.3.2 | WP plan | manual | 1d? | 2021-08-03 | 2021-08-03 |  |  |
| 65 | 1.1.7.3.3 | Publication | manual | 1d? | 2021-08-03 | 2021-08-03 |  |  |
| 66 | 1.1.8 | **WP3 Capture** |  | 87d? | 2021-08-03 | 2021-12-01 |  |  |
| 67 | 1.1.8.1 | WP definition | manual | 1d? | 2021-08-03 | 2021-08-03 |  |  |
| 68 | 1.1.8.2 | **Sub-project plan** |  | 0d? | 2021-08-03 | 2021-08-03 | 1499d |  |
| 69 | 1.1.8.2.1 | Timeline | manual | 1d? | 2021-08-03 | 2021-08-03 |  |  |
| 70 | 1.1.8.2.2 | Staffing | manual | 1d? | 2021-08-03 | 2021-08-03 |  |  |
| 71 | 1.1.8.2.3 | Equipment | manual | 1d? | 2021-08-03 | 2021-08-03 |  |  |
| 72 | 1.1.8.2.4 | Costs | manual | 1d? | 2021-08-03 | 2021-08-03 |  |  |
| 73 | 1.1.8.3 | **Reporting** |  | 81d | 2021-08-05 | 2021-11-25 | 0d |  |
| 74 | 1.1.8.3.1 | **Meetings with the PO** |  | 81d | 2021-08-05 | 2021-11-25 | 0d |  |
| 75 | 1.1.8.3.1.1 | Meetings with the PO 1 | manual | 1d | 2021-08-05 | 2021-08-05 |  | start no earlier than 2021-08-05 |
| 76 | 1.1.8.3.1.2 | Meetings with the PO 2 | manual | 1d | 2021-08-19 | 2021-08-19 |  | start no earlier than 2021-08-19 |
| 77 | 1.1.8.3.1.3 | Meetings with the PO 3 | manual | 1d | 2021-09-02 | 2021-09-02 |  | start no earlier than 2021-09-02 |
| 78 | 1.1.8.3.1.4 | Meetings with the PO 4 | manual | 1d | 2021-09-16 | 2021-09-16 |  | start no earlier than 2021-09-16 |
| 79 | 1.1.8.3.1.5 | Meetings with the PO 5 | manual | 1d | 2021-09-30 | 2021-09-30 |  | start no earlier than 2021-09-30 |
| 80 | 1.1.8.3.1.6 | Meetings with the PO 6 | manual | 1d | 2021-10-14 | 2021-10-14 |  | start no earlier than 2021-10-14 |
| 81 | 1.1.8.3.1.7 | Meetings with the PO 7 | manual | 1d | 2021-10-28 | 2021-10-28 |  | start no earlier than 2021-10-28 |
| 82 | 1.1.8.3.1.8 | Meetings with the PO 8 | manual | 1d | 2021-11-11 | 2021-11-11 |  | start no earlier than 2021-11-11 |
| 83 | 1.1.8.3.1.9 | Meetings with the PO 9 | manual | 1d | 2021-11-25 | 2021-11-25 |  | start no earlier than 2021-11-25 |
| 84 | 1.1.8.3.2 | WP plan | manual | 1d? | 2021-08-05 | 2021-08-05 |  |  |
| 85 | 1.1.8.3.3 | Publication | manual | 1d? | 2021-08-05 | 2021-08-05 |  |  |

| ID | WBS | Task | Type | Duration | Start | Finish | Total slack | Constraint |
| --- | --- | --- | --- | --- | --- | --- | --- | --- |
| 86 | 1.1.9 | **WP4 Ion-acoustic** |  | 87d? | 2021-08-03 | 2021-12-01 |  |  |
| 87 | 1.1.9.1 | WP definition | manual | 1d? | 2021-08-03 | 2021-08-03 |  |  |
| 88 | 1.1.9.2 | **Sub-project plan** |  | 0d? | 2021-08-03 | 2021-08-03 | 1499d |  |
| 89 | 1.1.9.2.1 | Timeline | manual | 1d? | 2021-08-03 | 2021-08-03 |  |  |
| 90 | 1.1.9.2.2 | Staffing | manual | 1d? | 2021-08-03 | 2021-08-03 |  |  |
| 91 | 1.1.9.2.3 | Equipment | manual | 1d? | 2021-08-03 | 2021-08-03 |  |  |
| 92 | 1.1.9.2.4 | Costs | manual | 1d? | 2021-08-03 | 2021-08-03 |  |  |
| 93 | 1.1.9.3 | **Reporting** |  | 81d | 2021-08-05 | 2021-11-25 | 0d |  |
| 94 | 1.1.9.3.1 | **Meetings with the PO** |  | 81d | 2021-08-05 | 2021-11-25 | 0d |  |
| 95 | 1.1.9.3.1.1 | Meetings with the PO 1 | manual | 1d | 2021-08-05 | 2021-08-05 |  | start no earlier than 2021-08-05 |
| 96 | 1.1.9.3.1.2 | Meetings with the PO 2 | manual | 1d | 2021-08-19 | 2021-08-19 |  | start no earlier than 2021-08-19 |
| 97 | 1.1.9.3.1.3 | Meetings with the PO 3 | manual | 1d | 2021-09-02 | 2021-09-02 |  | start no earlier than 2021-09-02 |
| 98 | 1.1.9.3.1.4 | Meetings with the PO 4 | manual | 1d | 2021-09-16 | 2021-09-16 |  | start no earlier than 2021-09-16 |
| 99 | 1.1.9.3.1.5 | Meetings with the PO 5 | manual | 1d | 2021-09-30 | 2021-09-30 |  | start no earlier than 2021-09-30 |
| 100 | 1.1.9.3.1.6 | Meetings with the PO 6 | manual | 1d | 2021-10-14 | 2021-10-14 |  | start no earlier than 2021-10-14 |
| 101 | 1.1.9.3.1.7 | Meetings with the PO 7 | manual | 1d | 2021-10-28 | 2021-10-28 |  | start no earlier than 2021-10-28 |
| 102 | 1.1.9.3.1.8 | Meetings with the PO 8 | manual | 1d | 2021-11-11 | 2021-11-11 |  | start no earlier than 2021-11-11 |
| 103 | 1.1.9.3.1.9 | Meetings with the PO 9 | manual | 1d | 2021-11-25 | 2021-11-25 |  | start no earlier than 2021-11-25 |
| 104 | 1.1.9.3.2 | WP plan | manual | 1d? | 2021-08-05 | 2021-08-05 |  |  |
| 105 | 1.1.9.3.3 | Publication | manual | 1d? | 2021-08-05 | 2021-08-05 |  |  |
| 106 | 1.1.10 | **WP5 Vertical Beamline** |  | 87d? | 2021-08-03 | 2021-12-01 |  |  |
| 107 | 1.1.10.1 | WP definition | manual | 1d? | 2021-08-03 | 2021-08-03 |  |  |
| 108 | 1.1.10.2 | **Sub-project plan** |  | 0d? | 2021-08-03 | 2021-08-03 | 1499d |  |
| 109 | 1.1.10.2.1 | Timeline | manual | 1d? | 2021-08-03 | 2021-08-03 |  |  |
| 110 | 1.1.10.2.2 | Staffing | manual | 1d? | 2021-08-03 | 2021-08-03 |  |  |
| 111 | 1.1.10.2.3 | Equipment | manual | 1d? | 2021-08-03 | 2021-08-03 |  |  |
| 112 | 1.1.10.2.4 | Costs | manual | 1d? | 2021-08-03 | 2021-08-03 |  |  |

| ID | WBS | Task | Type | Duration | Start | Finish | Total slack | Constraint |
| --- | --- | --- | --- | --- | --- | --- | --- | --- |
| 113 | 1.1.10.3 | **Reporting** |  | 81d | 2021-08-05 | 2021-11-25 | 0d |  |
| 114 | 1.1.10.3.1 | **Meetings with the PO** |  | 81d | 2021-08-05 | 2021-11-25 | 0d |  |
| 115 | 1.1.10.3.1.1 | Meetings with the PO 1 | manual | 1d | 2021-08-05 | 2021-08-05 |  | start no earlier than 2021-08-05 |
| 116 | 1.1.10.3.1.2 | Meetings with the PO 2 | manual | 1d | 2021-08-19 | 2021-08-19 |  | start no earlier than 2021-08-19 |
| 117 | 1.1.10.3.1.3 | Meetings with the PO 3 | manual | 1d | 2021-09-02 | 2021-09-02 |  | start no earlier than 2021-09-02 |
| 118 | 1.1.10.3.1.4 | Meetings with the PO 4 | manual | 1d | 2021-09-16 | 2021-09-16 |  | start no earlier than 2021-09-16 |
| 119 | 1.1.10.3.1.5 | Meetings with the PO 5 | manual | 1d | 2021-09-30 | 2021-09-30 |  | start no earlier than 2021-09-30 |
| 120 | 1.1.10.3.1.6 | Meetings with the PO 6 | manual | 1d | 2021-10-14 | 2021-10-14 |  | start no earlier than 2021-10-14 |
| 121 | 1.1.10.3.1.7 | Meetings with the PO 7 | manual | 1d | 2021-10-28 | 2021-10-28 |  | start no earlier than 2021-10-28 |
| 122 | 1.1.10.3.1.8 | Meetings with the PO 8 | manual | 1d | 2021-11-11 | 2021-11-11 |  | start no earlier than 2021-11-11 |
| 123 | 1.1.10.3.1.9 | Meetings with the PO 9 | manual | 1d | 2021-11-25 | 2021-11-25 |  | start no earlier than 2021-11-25 |
| 124 | 1.1.10.3.2 | WP plan | manual | 1d? | 2021-08-05 | 2021-08-05 |  |  |
| 125 | 1.1.10.3.3 | Publication | manual | 1d? | 2021-08-05 | 2021-08-05 |  |  |
| 126 | 1.1.11 | **WP6 System design** |  | 87d? | 2021-08-03 | 2021-12-01 |  |  |
| 127 | 1.1.11.1 | WP definition | manual | 1d? | 2021-08-03 | 2021-08-03 |  |  |
| 128 | 1.1.11.2 | **Sub-project plan** |  | 0d? | 2021-08-03 | 2021-08-03 | 1499d |  |
| 129 | 1.1.11.2.1 | Timeline | manual | 1d? | 2021-08-03 | 2021-08-03 |  |  |
| 130 | 1.1.11.2.2 | Staffing | manual | 1d? | 2021-08-03 | 2021-08-03 |  |  |
| 131 | 1.1.11.2.3 | Equipment | manual | 1d? | 2021-08-03 | 2021-08-03 |  |  |
| 132 | 1.1.11.2.4 | Costs | manual | 1d? | 2021-08-03 | 2021-08-03 |  |  |
| 133 | 1.1.11.3 | **Reporting** |  | 81d | 2021-08-05 | 2021-11-25 | 0d |  |
| 134 | 1.1.11.3.1 | **Meetings with the PO** |  | 81d | 2021-08-05 | 2021-11-25 | 0d |  |
| 135 | 1.1.11.3.1.1 | Meetings with the PO 1 | manual | 1d | 2021-08-05 | 2021-08-05 |  | start no earlier than 2021-08-05 |
| 136 | 1.1.11.3.1.2 | Meetings with the PO 2 | manual | 1d | 2021-08-19 | 2021-08-19 |  | start no earlier than 2021-08-19 |
| 137 | 1.1.11.3.1.3 | Meetings with the PO 3 | manual | 1d | 2021-09-02 | 2021-09-02 |  | start no earlier than 2021-09-02 |
| 138 | 1.1.11.3.1.4 | Meetings with the PO 4 | manual | 1d | 2021-09-16 | 2021-09-16 |  | start no earlier than 2021-09-16 |
| 139 | 1.1.11.3.1.5 | Meetings with the PO 5 | manual | 1d | 2021-09-30 | 2021-09-30 |  | start no earlier than 2021-09-30 |
| 140 | 1.1.11.3.1.6 | Meetings with the PO 6 | manual | 1d | 2021-10-14 | 2021-10-14 |  | start no earlier than 2021-10-14 |
| 141 | 1.1.11.3.1.7 | Meetings with the PO 7 | manual | 1d | 2021-10-28 | 2021-10-28 |  | start no earlier than 2021-10-28 |
| 142 | 1.1.11.3.1.8 | Meetings with the PO 8 | manual | 1d | 2021-11-11 | 2021-11-11 |  | start no earlier than 2021-11-11 |
| 143 | 1.1.11.3.1.9 | Meetings with the PO 9 | manual | 1d | 2021-11-25 | 2021-11-25 |  | start no earlier than 2021-11-25 |
| 144 | 1.1.11.3.2 | WP plan | manual | 1d? | 2021-08-05 | 2021-08-05 |  |  |
| 145 | 1.1.11.3.3 | Publication | manual | 1d? | 2021-08-05 | 2021-08-05 |  |  |

| ID | WBS | Task | Type | Duration | Start | Finish | Predecessors | Total slack | Free slack | Constraint |
| --- | --- | --- | --- | --- | --- | --- | --- | --- | --- | --- |
| 146 | 1.2 | **LhARA Project** |  | 1326d? | 2022-04-01 | 2027-04-30 |  |  |  |  |
| 147 | 1.2.1 | Launch of LhARA project | milestone, manual | 0d | 2022-04-01 | 2022-04-01 |  |  |  |  |
| 148 | 1.2.2 | Conseptual Design Report for the facility | milestone, manual | 0d | 2024-03-31 | 2024-03-31 |  |  |  |  |
| 149 | 1.2.3 | Technical Design Report (TFD2) for Stage 2 | milestone, manual | 0d | 2027-03-31 | 2027-03-31 |  |  |  |  |
| 150 | 1.2.4 | Technical Design Report for Stage 1 | milestone, manual | 0d | 2025-03-31 | 2025-03-31 |  |  |  |  |
| 151 | 1.2.5 | **WP1 Project Management** |  | 1326d? | 2022-04-01 | 2027-04-30 |  |  |  |  |
| 152 | 1.2.5.1 | **Reporting** |  | 1326d | 2022-04-01 | 2027-04-30 |  |  |  |  |
| 153 | 1.2.5.1.1 | Prepation for OsC meeting | manual | 10d | 2022-10-17 | 2022-10-28 | 167 |  |  |  |
| 154 | 1.2.5.1.2 | Prepation for OsC meeting | manual | 10d | 2023-04-17 | 2023-04-28 | 170 |  |  |  |
| 155 | 1.2.5.1.3 | Prepation for OsC meeting |  | 10d | 2023-10-17 | 2023-10-30 | 173 | 913d | 1d |  |
| 156 | 1.2.5.1.4 | Prepation for OsC meeting |  | 10d | 2024-04-15 | 2024-04-26 | 176 | 784d | 2d |  |
| 157 | 1.2.5.1.5 | Prepation for OsC meeting | manual | 10d | 2024-10-09 | 2024-10-22 | 179 |  |  |  |
| 158 | 1.2.5.1.6 | Prepation for OsC meeting |  | 10d | 2025-04-16 | 2025-04-29 | 182 | 522d | 0d |  |
| 159 | 1.2.5.1.7 | Prepation for OsC meeting |  | 10d | 2025-10-17 | 2025-10-30 | 185 | 390d | 3d |  |
| 160 | 1.2.5.1.8 | Prepation for OsC meeting |  | 10d | 2026-04-16 | 2026-04-29 | 188 | 261d | 4d |  |
| 161 | 1.2.5.1.9 | Prepation for OsC meeting |  | 10d | 2026-10-19 | 2026-10-30 | 191 | 129d | 2d |  |
| 162 | 1.2.5.1.10 | Prepation for OsC meeting |  | 10d | 2027-04-16 | 2027-04-29 | 194 | 0d |  |  |
| 163 | 1.2.5.1.11 | **LhARA Project Group meeting** |  | 1308d | 2022-04-12 | 2027-04-15 |  | 0d |  |  |
| 164 | 1.2.5.1.11.1 | LhARA Project Group meeting 1 | manual | 1d | 2022-04-12 | 2022-04-12 |  |  |  | start no earlier than 2022-04-12 |
| 165 | 1.2.5.1.11.2 | LhARA Project Group meeting 2 | manual | 1d | 2022-06-14 | 2022-06-14 |  |  |  | start no earlier than 2022-06-14 |
| 166 | 1.2.5.1.11.3 | LhARA Project Group meeting 3 | manual | 1d | 2022-08-09 | 2022-08-09 |  |  |  | start no earlier than 2022-08-09 |
| 167 | 1.2.5.1.11.4 | LhARA Project Group meeting 4 | manual | 1d | 2022-10-14 | 2022-10-14 | 739, 767, 790, 801 |  |  | start no earlier than 2022-10-11 |
| 168 | 1.2.5.1.11.5 | LhARA Project Group meeting 5 | manual | 1d | 2022-12-13 | 2022-12-13 |  |  |  | start no earlier than 2022-12-13 |
| 169 | 1.2.5.1.11.6 | LhARA Project Group meeting 6 | manual | 1d | 2023-02-14 | 2023-02-14 |  |  |  | start no earlier than 2023-02-14 |
| 170 | 1.2.5.1.11.7 | LhARA Project Group meeting 7 | manual | 1d | 2023-04-14 | 2023-04-14 | 740, 768, 791, 802 |  |  | start no earlier than 2023-04-14 |
| 171 | 1.2.5.1.11.8 | LhARA Project Group meeting 8 | manual | 1d | 2023-06-13 | 2023-06-13 |  |  |  | start no earlier than 2023-06-13 |
| 172 | 1.2.5.1.11.9 | LhARA Project Group meeting 9 | manual | 1d | 2023-08-08 | 2023-08-08 |  |  |  | start no earlier than 2023-08-08 |
| 173 | 1.2.5.1.11.10 | LhARA Project Group meeting 10 | manual | 1d | 2023-10-16 | 2023-10-16 | 741, 769, 792, 803 |  |  | start no earlier than 2023-10-10 |
| 174 | 1.2.5.1.11.11 | LhARA Project Group meeting 11 | manual | 1d | 2023-12-12 | 2023-12-12 |  |  |  | start no earlier than 2023-12-12 |
| 175 | 1.2.5.1.11.12 | LhARA Project Group meeting 12 | manual | 1d | 2024-02-13 | 2024-02-13 |  |  |  | start no earlier than 2024-02-13 |
| 176 | 1.2.5.1.11.13 | LhARA Project Group meeting 13 | manual | 1d | 2024-04-12 | 2024-04-12 | 742, 770, 793, 804 |  |  | start no earlier than 2024-04-12 |
| 177 | 1.2.5.1.11.14 | LhARA Project Group meeting 14 | manual | 1d | 2024-06-11 | 2024-06-11 |  |  |  | start no earlier than 2024-06-11 |
| 178 | 1.2.5.1.11.15 | LhARA Project Group meeting 15 | manual | 1d | 2024-08-13 | 2024-08-13 |  |  |  | start no earlier than 2024-08-13 |
| 179 | 1.2.5.1.11.16 | LhARA Project Group meeting 16 |  | 1d | 2024-10-07 | 2024-10-07 | 743, 771, 794, 805 | 658d | 1d | start no earlier than 2024-10-03 |
| 180 | 1.2.5.1.11.17 | LhARA Project Group meeting 17 | manual | 1d | 2024-12-10 | 2024-12-10 |  |  |  | start no earlier than 2024-12-10 |
| 181 | 1.2.5.1.11.18 | LhARA Project Group meeting 18 | manual | 1d | 2025-02-11 | 2025-02-11 |  |  |  | start no earlier than 2025-02-11 |
| 182 | 1.2.5.1.11.19 | LhARA Project Group meeting 19 | manual | 1d | 2025-04-15 | 2025-04-15 | 744, 772, 795, 806 |  |  | start no earlier than 2025-04-08 |
| 183 | 1.2.5.1.11.20 | LhARA Project Group meeting 20 | manual | 1d | 2025-06-10 | 2025-06-10 |  |  |  | start no earlier than 2025-06-10 |
| 184 | 1.2.5.1.11.21 | LhARA Project Group meeting 21 | manual | 1d | 2025-08-12 | 2025-08-12 |  |  |  | start no earlier than 2025-08-12 |
| 185 | 1.2.5.1.11.22 | LhARA Project Group meeting 22 | manual | 1d | 2025-10-16 | 2025-10-16 | 745, 773, 796, 807 |  |  | start no earlier than 2025-10-14 |
| 186 | 1.2.5.1.11.23 | LhARA Project Group meeting 23 | manual | 1d | 2025-12-09 | 2025-12-09 |  |  |  | start no earlier than 2025-12-09 |
| 187 | 1.2.5.1.11.24 | LhARA Project Group meeting 24 | manual | 1d | 2026-02-10 | 2026-02-10 |  |  |  | start no earlier than 2026-02-10 |
| 188 | 1.2.5.1.11.25 | LhARA Project Group meeting 25 | manual | 1d | 2026-04-15 | 2026-04-15 | 746, 774, 797, 808 |  |  | start no earlier than 2026-04-14 |
| 189 | 1.2.5.1.11.26 | LhARA Project Group meeting 26 | manual | 1d | 2026-06-09 | 2026-06-09 |  |  |  | start no earlier than 2026-06-09 |
| 190 | 1.2.5.1.11.27 | LhARA Project Group meeting 27 | manual | 1d | 2026-08-11 | 2026-08-11 |  |  |  | start no earlier than 2026-08-11 |
| 191 | 1.2.5.1.11.28 | LhARA Project Group meeting 28 | manual | 1d | 2026-10-16 | 2026-10-16 | 747, 775, 798, 809 |  |  | start no earlier than 2026-10-13 |
| 192 | 1.2.5.1.11.29 | LhARA Project Group meeting 29 | manual | 1d | 2026-12-08 | 2026-12-08 |  |  |  | start no earlier than 2026-12-08 |
| 193 | 1.2.5.1.11.30 | LhARA Project Group meeting 30 | manual | 1d | 2027-02-09 | 2027-02-09 |  |  |  | start no earlier than 2027-02-09 |
| 194 | 1.2.5.1.11.31 | LhARA Project Group meeting 31 | manual | 1d | 2027-04-15 | 2027-04-15 | 748, 776, 799, 810 |  |  | start no earlier than 2027-03-31 |

| ID | WBS | Task | Type | Duration | Start | Finish | Predecessors | Total slack | Constraint |
| --- | --- | --- | --- | --- | --- | --- | --- | --- | --- |
| 195 | 1.2.5.1.12 | **STFC Oversight committee (OsC)** |  | 1326d | 2022-04-01 | 2027-04-30 |  |  |  |
| 196 | 1.2.5.1.12.1 | **OsC meetings** |  | 1307d | 2022-04-28 | 2027-04-30 |  | 0d |  |
| 197 | 1.2.5.1.12.1.1 | OsC meeting 1 | manual | 1d | 2022-04-28 | 2022-04-28 |  |  | start no earlier than 2022-04-28 |
| 198 | 1.2.5.1.12.1.2 | OsC meeting 2 |  | 1d | 2022-10-31 | 2022-10-31 | 153 | 1174d | start no earlier than 2022-10-27 |
| 199 | 1.2.5.1.12.1.3 | OsC meeting 3 | manual | 1d | 2023-05-04 | 2023-05-04 | 154 |  | start no earlier than 2023-04-27 |
| 200 | 1.2.5.1.12.1.4 | OsC meeting 4 | manual | 1d | 2023-11-01 | 2023-11-01 | 155 |  | start no earlier than 2023-10-26 |
| 201 | 1.2.5.1.12.1.5 | OsC meeting 5 | manual | 1d | 2024-05-01 | 2024-05-01 | 156 |  | start no earlier than 2024-04-25 |
| 202 | 1.2.5.1.12.1.6 | OsC meeting 6 | manual | 1d | 2024-10-30 | 2024-10-30 | 157 |  | start no earlier than 2024-10-24 |
| 203 | 1.2.5.1.12.1.7 | OsC meeting 7 | manual | 1d | 2025-04-30 | 2025-04-30 | 158 |  | start no earlier than 2025-04-24 |
| 204 | 1.2.5.1.12.1.8 | OsC meeting 8 | manual | 1d | 2025-11-05 | 2025-11-05 | 159 |  | start no earlier than 2025-10-23 |
| 205 | 1.2.5.1.12.1.9 | OsC meeting 9 | manual | 1d | 2026-05-06 | 2026-05-06 | 160 |  | start no earlier than 2026-04-23 |
| 206 | 1.2.5.1.12.1.10 | OsC meeting 10 | manual | 1d | 2026-11-04 | 2026-11-04 | 161 |  | start no earlier than 2026-11-04 |
| 207 | 1.2.5.1.12.1.11 | OsC meeting 11 |  | 1d | 2027-04-30 | 2027-04-30 | 162 | 0d | start no earlier than 2027-03-31 |
| 208 | 1.2.5.2 | **Outreach** |  | 1041d | 2022-10-20 | 2026-10-15 |  | 0d |  |
| 209 | 1.2.5.2.1 | Radiobiology | manual | 1d? | 2022-10-20 | 2022-10-20 |  |  |  |
| 210 | 1.2.5.2.2 | Clinician Engagement | manual | 1d? | 2022-10-20 | 2022-10-20 |  |  |  |
| 211 | 1.2.5.2.3 | Public Engagement | manual | 1d? | 2022-10-20 | 2022-10-20 |  |  |  |
| 212 | 1.2.5.2.4 | **Patient Engagement** |  | 1041d | 2022-10-20 | 2026-10-15 |  | 0d |  |
| 213 | 1.2.5.2.4.1 | **Patient Input** |  | 1041d | 2022-10-20 | 2026-10-15 |  | 0d |  |
| 214 | 1.2.5.2.4.1.1 | Patient Input 1 | manual | 1d | 2022-10-20 | 2022-10-20 |  |  | start no earlier than 2022-10-20 |
| 215 | 1.2.5.2.4.1.2 | Patient Input 2 | manual | 1d | 2023-04-20 | 2023-04-20 |  |  | start no earlier than 2023-04-20 |
| 216 | 1.2.5.2.4.1.3 | Patient Input 3 | manual | 1d | 2023-10-19 | 2023-10-19 |  |  | start no earlier than 2023-10-19 |
| 217 | 1.2.5.2.4.1.4 | Patient Input 4 | manual | 1d | 2024-04-18 | 2024-04-18 |  |  | start no earlier than 2024-04-18 |
| 218 | 1.2.5.2.4.1.5 | Patient Input 5 | manual | 1d | 2024-10-17 | 2024-10-17 |  |  | start no earlier than 2024-10-17 |
| 219 | 1.2.5.2.4.1.6 | Patient Input 6 | manual | 1d | 2025-04-17 | 2025-04-17 |  |  | start no earlier than 2025-04-17 |
| 220 | 1.2.5.2.4.1.7 | Patient Input 7 | manual | 1d | 2025-10-16 | 2025-10-16 |  |  | start no earlier than 2025-10-16 |
| 221 | 1.2.5.2.4.1.8 | Patient Input 8 | manual | 1d | 2026-04-16 | 2026-04-16 |  |  | start no earlier than 2026-04-16 |
| 222 | 1.2.5.2.4.1.9 | Patient Input 9 | manual | 1d | 2026-10-15 | 2026-10-15 |  |  | start no earlier than 2026-10-15 |

| ID | WBS | Task | Type | Duration | Start | Finish | Total slack | Constraint |
| --- | --- | --- | --- | --- | --- | --- | --- | --- |
| 223 | 1.2.5.3 | **Meetings** |  | 1477d? | 2021-08-03 | 2027-03-31 | 0d |  |
| 224 | 1.2.5.3.1 | **WP1 meetings** |  | 1301d | 2022-04-06 | 2027-03-31 | 0d |  |
| 225 | 1.2.5.3.1.1 | WP1 meetings 1 | manual | 1d | 2022-04-06 | 2022-04-06 |  | start no earlier than 2022-04-06 |
| 226 | 1.2.5.3.1.2 | WP1 meetings 2 | manual | 1d | 2022-04-13 | 2022-04-13 |  | start no earlier than 2022-04-13 |
| 227 | 1.2.5.3.1.3 | WP1 meetings 3 | manual | 1d | 2022-04-20 | 2022-04-20 |  | start no earlier than 2022-04-20 |
| 228 | 1.2.5.3.1.4 | WP1 meetings 4 | manual | 1d | 2022-04-27 | 2022-04-27 |  | start no earlier than 2022-04-27 |
| 229 | 1.2.5.3.1.5 | WP1 meetings 5 | manual | 1d | 2022-05-04 | 2022-05-04 |  | start no earlier than 2022-05-04 |
| 230 | 1.2.5.3.1.6 | WP1 meetings 6 | manual | 1d | 2022-05-11 | 2022-05-11 |  | start no earlier than 2022-05-11 |
| 231 | 1.2.5.3.1.7 | WP1 meetings 7 | manual | 1d | 2022-05-18 | 2022-05-18 |  | start no earlier than 2022-05-18 |
| 232 | 1.2.5.3.1.8 | WP1 meetings 8 | manual | 1d | 2022-05-25 | 2022-05-25 |  | start no earlier than 2022-05-25 |
| 233 | 1.2.5.3.1.9 | WP1 meetings 9 | manual | 1d | 2022-06-01 | 2022-06-01 |  | start no earlier than 2022-06-01 |
| 234 | 1.2.5.3.1.10 | WP1 meetings 10 | manual | 1d | 2022-06-08 | 2022-06-08 |  | start no earlier than 2022-06-08 |
| 235 | 1.2.5.3.1.11 | WP1 meetings 11 | manual | 1d | 2022-06-15 | 2022-06-15 |  | start no earlier than 2022-06-15 |
| 236 | 1.2.5.3.1.12 | WP1 meetings 12 | manual | 1d | 2022-06-22 | 2022-06-22 |  | start no earlier than 2022-06-22 |
| 237 | 1.2.5.3.1.13 | WP1 meetings 13 | manual | 1d | 2022-06-29 | 2022-06-29 |  | start no earlier than 2022-06-29 |
| 238 | 1.2.5.3.1.14 | WP1 meetings 14 | manual | 1d | 2022-07-06 | 2022-07-06 |  | start no earlier than 2022-07-06 |
| 239 | 1.2.5.3.1.15 | WP1 meetings 15 | manual | 1d | 2022-07-13 | 2022-07-13 |  | start no earlier than 2022-07-13 |
| 240 | 1.2.5.3.1.16 | WP1 meetings 16 | manual | 1d | 2022-07-20 | 2022-07-20 |  | start no earlier than 2022-07-20 |
| 241 | 1.2.5.3.1.17 | WP1 meetings 17 | manual | 1d | 2022-07-27 | 2022-07-27 |  | start no earlier than 2022-07-27 |
| 242 | 1.2.5.3.1.18 | WP1 meetings 18 | manual | 1d | 2022-08-03 | 2022-08-03 |  | start no earlier than 2022-08-03 |
| 243 | 1.2.5.3.1.19 | WP1 meetings 19 | manual | 1d | 2022-08-10 | 2022-08-10 |  | start no earlier than 2022-08-10 |
| 244 | 1.2.5.3.1.20 | WP1 meetings 20 | manual | 1d | 2022-08-17 | 2022-08-17 |  | start no earlier than 2022-08-17 |
| 245 | 1.2.5.3.1.21 | WP1 meetings 21 | manual | 1d | 2022-08-24 | 2022-08-24 |  | start no earlier than 2022-08-24 |
| 246 | 1.2.5.3.1.22 | WP1 meetings 22 | manual | 1d | 2022-08-31 | 2022-08-31 |  | start no earlier than 2022-08-31 |
| 247 | 1.2.5.3.1.23 | WP1 meetings 23 | manual | 1d | 2022-09-07 | 2022-09-07 |  | start no earlier than 2022-09-07 |
| 248 | 1.2.5.3.1.24 | WP1 meetings 24 | manual | 1d | 2022-09-14 | 2022-09-14 |  | start no earlier than 2022-09-14 |
| 249 | 1.2.5.3.1.25 | WP1 meetings 25 | manual | 1d | 2022-09-21 | 2022-09-21 |  | start no earlier than 2022-09-21 |
| 250 | 1.2.5.3.1.26 | WP1 meetings 26 | manual | 1d | 2022-09-28 | 2022-09-28 |  | start no earlier than 2022-09-28 |
| 251 | 1.2.5.3.1.27 | WP1 meetings 27 | manual | 1d | 2022-10-05 | 2022-10-05 |  | start no earlier than 2022-10-05 |
| 252 | 1.2.5.3.1.28 | WP1 meetings 28 | manual | 1d | 2022-10-12 | 2022-10-12 |  | start no earlier than 2022-10-12 |
| 253 | 1.2.5.3.1.29 | WP1 meetings 29 | manual | 1d | 2022-10-19 | 2022-10-19 |  | start no earlier than 2022-10-19 |
| 254 | 1.2.5.3.1.30 | WP1 meetings 30 | manual | 1d | 2022-10-26 | 2022-10-26 |  | start no earlier than 2022-10-26 |
| 255 | 1.2.5.3.1.31 | WP1 meetings 31 | manual | 1d | 2022-11-02 | 2022-11-02 |  | start no earlier than 2022-11-02 |
| 256 | 1.2.5.3.1.32 | WP1 meetings 32 | manual | 1d | 2022-11-09 | 2022-11-09 |  | start no earlier than 2022-11-09 |
| 257 | 1.2.5.3.1.33 | WP1 meetings 33 | manual | 1d | 2022-11-16 | 2022-11-16 |  | start no earlier than 2022-11-16 |
| 258 | 1.2.5.3.1.34 | WP1 meetings 34 | manual | 1d | 2022-11-23 | 2022-11-23 |  | start no earlier than 2022-11-23 |
| 259 | 1.2.5.3.1.35 | WP1 meetings 35 | manual | 1d | 2022-11-30 | 2022-11-30 |  | start no earlier than 2022-11-30 |
| 260 | 1.2.5.3.1.36 | WP1 meetings 36 | manual | 1d | 2022-12-07 | 2022-12-07 |  | start no earlier than 2022-12-07 |
| 261 | 1.2.5.3.1.37 | WP1 meetings 37 | manual | 1d | 2022-12-14 | 2022-12-14 |  | start no earlier than 2022-12-14 |
| 262 | 1.2.5.3.1.38 | WP1 meetings 38 | manual | 1d | 2022-12-21 | 2022-12-21 |  | start no earlier than 2022-12-21 |
| 263 | 1.2.5.3.1.39 | WP1 meetings 39 | manual | 1d | 2022-12-28 | 2022-12-28 |  | start no earlier than 2022-12-28 |
| 264 | 1.2.5.3.1.40 | WP1 meetings 40 | manual | 1d | 2023-01-04 | 2023-01-04 |  | start no earlier than 2023-01-04 |
| 265 | 1.2.5.3.1.41 | WP1 meetings 41 | manual | 1d | 2023-01-11 | 2023-01-11 |  | start no earlier than 2023-01-11 |
| 266 | 1.2.5.3.1.42 | WP1 meetings 42 | manual | 1d | 2023-01-18 | 2023-01-18 |  | start no earlier than 2023-01-18 |
| 267 | 1.2.5.3.1.43 | WP1 meetings 43 | manual | 1d | 2023-01-25 | 2023-01-25 |  | start no earlier than 2023-01-25 |
| 268 | 1.2.5.3.1.44 | WP1 meetings 44 | manual | 1d | 2023-02-01 | 2023-02-01 |  | start no earlier than 2023-02-01 |
| 269 | 1.2.5.3.1.45 | WP1 meetings 45 | manual | 1d | 2023-02-08 | 2023-02-08 |  | start no earlier than 2023-02-08 |
| 270 | 1.2.5.3.1.46 | WP1 meetings 46 | manual | 1d | 2023-02-15 | 2023-02-15 |  | start no earlier than 2023-02-15 |
| 271 | 1.2.5.3.1.47 | WP1 meetings 47 | manual | 1d | 2023-02-22 | 2023-02-22 |  | start no earlier than 2023-02-22 |
| 272 | 1.2.5.3.1.48 | WP1 meetings 48 | manual | 1d | 2023-03-01 | 2023-03-01 |  | start no earlier than 2023-03-01 |
| 273 | 1.2.5.3.1.49 | WP1 meetings 49 | manual | 1d | 2023-03-08 | 2023-03-08 |  | start no earlier than 2023-03-08 |
| 274 | 1.2.5.3.1.50 | WP1 meetings 50 | manual | 1d | 2023-03-15 | 2023-03-15 |  | start no earlier than 2023-03-15 |
| 275 | 1.2.5.3.1.51 | WP1 meetings 51 | manual | 1d | 2023-03-22 | 2023-03-22 |  | start no earlier than 2023-03-22 |
| 276 | 1.2.5.3.1.52 | WP1 meetings 52 | manual | 1d | 2023-03-29 | 2023-03-29 |  | start no earlier than 2023-03-29 |
| 277 | 1.2.5.3.1.53 | WP1 meetings 53 | manual | 1d | 2023-04-05 | 2023-04-05 |  | start no earlier than 2023-04-05 |
| 278 | 1.2.5.3.1.54 | WP1 meetings 54 | manual | 1d | 2023-04-12 | 2023-04-12 |  | start no earlier than 2023-04-12 |
| 279 | 1.2.5.3.1.55 | WP1 meetings 55 | manual | 1d | 2023-04-19 | 2023-04-19 |  | start no earlier than 2023-04-19 |
| 280 | 1.2.5.3.1.56 | WP1 meetings 56 | manual | 1d | 2023-04-26 | 2023-04-26 |  | start no earlier than 2023-04-26 |
| 281 | 1.2.5.3.1.57 | WP1 meetings 57 | manual | 1d | 2023-05-03 | 2023-05-03 |  | start no earlier than 2023-05-03 |
| 282 | 1.2.5.3.1.58 | WP1 meetings 58 | manual | 1d | 2023-05-10 | 2023-05-10 |  | start no earlier than 2023-05-10 |
| 283 | 1.2.5.3.1.59 | WP1 meetings 59 | manual | 1d | 2023-05-17 | 2023-05-17 |  | start no earlier than 2023-05-17 |
| 284 | 1.2.5.3.1.60 | WP1 meetings 60 | manual | 1d | 2023-05-24 | 2023-05-24 |  | start no earlier than 2023-05-24 |
| 285 | 1.2.5.3.1.61 | WP1 meetings 61 | manual | 1d | 2023-05-31 | 2023-05-31 |  | start no earlier than 2023-05-31 |
| 286 | 1.2.5.3.1.62 | WP1 meetings 62 | manual | 1d | 2023-06-07 | 2023-06-07 |  | start no earlier than 2023-06-07 |
| 287 | 1.2.5.3.1.63 | WP1 meetings 63 | manual | 1d | 2023-06-14 | 2023-06-14 |  | start no earlier than 2023-06-14 |
| 288 | 1.2.5.3.1.64 | WP1 meetings 64 | manual | 1d | 2023-06-21 | 2023-06-21 |  | start no earlier than 2023-06-21 |
| 289 | 1.2.5.3.1.65 | WP1 meetings 65 | manual | 1d | 2023-06-28 | 2023-06-28 |  | start no earlier than 2023-06-28 |
| 290 | 1.2.5.3.1.66 | WP1 meetings 66 | manual | 1d | 2023-07-05 | 2023-07-05 |  | start no earlier than 2023-07-05 |
| 291 | 1.2.5.3.1.67 | WP1 meetings 67 | manual | 1d | 2023-07-12 | 2023-07-12 |  | start no earlier than 2023-07-12 |
| 292 | 1.2.5.3.1.68 | WP1 meetings 68 | manual | 1d | 2023-07-19 | 2023-07-19 |  | start no earlier than 2023-07-19 |

| ID | WBS | Task | Type | Duration | Start | Finish | Constraint |
| --- | --- | --- | --- | --- | --- | --- | --- |
| 293 | 1.2.5.3.1.69 | WP1 meetings 69 | manual | 1d | 2023-07-26 | 2023-07-26 | start no earlier than 2023-07-26 |
| 294 | 1.2.5.3.1.70 | WP1 meetings 70 | manual | 1d | 2023-08-02 | 2023-08-02 | start no earlier than 2023-08-02 |
| 295 | 1.2.5.3.1.71 | WP1 meetings 71 | manual | 1d | 2023-08-09 | 2023-08-09 | start no earlier than 2023-08-09 |
| 296 | 1.2.5.3.1.72 | WP1 meetings 72 | manual | 1d | 2023-08-16 | 2023-08-16 | start no earlier than 2023-08-16 |
| 297 | 1.2.5.3.1.73 | WP1 meetings 73 | manual | 1d | 2023-08-23 | 2023-08-23 | start no earlier than 2023-08-23 |
| 298 | 1.2.5.3.1.74 | WP1 meetings 74 | manual | 1d | 2023-08-30 | 2023-08-30 | start no earlier than 2023-08-30 |
| 299 | 1.2.5.3.1.75 | WP1 meetings 75 | manual | 1d | 2023-09-06 | 2023-09-06 | start no earlier than 2023-09-06 |
| 300 | 1.2.5.3.1.76 | WP1 meetings 76 | manual | 1d | 2023-09-13 | 2023-09-13 | start no earlier than 2023-09-13 |
| 301 | 1.2.5.3.1.77 | WP1 meetings 77 | manual | 1d | 2023-09-20 | 2023-09-20 | start no earlier than 2023-09-20 |
| 302 | 1.2.5.3.1.78 | WP1 meetings 78 | manual | 1d | 2023-09-27 | 2023-09-27 | start no earlier than 2023-09-27 |
| 303 | 1.2.5.3.1.79 | WP1 meetings 79 | manual | 1d | 2023-10-04 | 2023-10-04 | start no earlier than 2023-10-04 |
| 304 | 1.2.5.3.1.80 | WP1 meetings 80 | manual | 1d | 2023-10-11 | 2023-10-11 | start no earlier than 2023-10-11 |
| 305 | 1.2.5.3.1.81 | WP1 meetings 81 | manual | 1d | 2023-10-18 | 2023-10-18 | start no earlier than 2023-10-18 |
| 306 | 1.2.5.3.1.82 | WP1 meetings 82 | manual | 1d | 2023-10-25 | 2023-10-25 | start no earlier than 2023-10-25 |
| 307 | 1.2.5.3.1.83 | WP1 meetings 83 | manual | 1d | 2023-11-01 | 2023-11-01 | start no earlier than 2023-11-01 |
| 308 | 1.2.5.3.1.84 | WP1 meetings 84 | manual | 1d | 2023-11-08 | 2023-11-08 | start no earlier than 2023-11-08 |
| 309 | 1.2.5.3.1.85 | WP1 meetings 85 | manual | 1d | 2023-11-15 | 2023-11-15 | start no earlier than 2023-11-15 |
| 310 | 1.2.5.3.1.86 | WP1 meetings 86 | manual | 1d | 2023-11-22 | 2023-11-22 | start no earlier than 2023-11-22 |
| 311 | 1.2.5.3.1.87 | WP1 meetings 87 | manual | 1d | 2023-11-29 | 2023-11-29 | start no earlier than 2023-11-29 |
| 312 | 1.2.5.3.1.88 | WP1 meetings 88 | manual | 1d | 2023-12-06 | 2023-12-06 | start no earlier than 2023-12-06 |
| 313 | 1.2.5.3.1.89 | WP1 meetings 89 | manual | 1d | 2023-12-13 | 2023-12-13 | start no earlier than 2023-12-13 |
| 314 | 1.2.5.3.1.90 | WP1 meetings 90 | manual | 1d | 2023-12-20 | 2023-12-20 | start no earlier than 2023-12-20 |
| 315 | 1.2.5.3.1.91 | WP1 meetings 91 | manual | 1d | 2023-12-27 | 2023-12-27 | start no earlier than 2023-12-27 |
| 316 | 1.2.5.3.1.92 | WP1 meetings 92 | manual | 1d | 2024-01-03 | 2024-01-03 | start no earlier than 2024-01-03 |
| 317 | 1.2.5.3.1.93 | WP1 meetings 93 | manual | 1d | 2024-01-10 | 2024-01-10 | start no earlier than 2024-01-10 |
| 318 | 1.2.5.3.1.94 | WP1 meetings 94 | manual | 1d | 2024-01-17 | 2024-01-17 | start no earlier than 2024-01-17 |
| 319 | 1.2.5.3.1.95 | WP1 meetings 95 | manual | 1d | 2024-01-24 | 2024-01-24 | start no earlier than 2024-01-24 |
| 320 | 1.2.5.3.1.96 | WP1 meetings 96 | manual | 1d | 2024-01-31 | 2024-01-31 | start no earlier than 2024-01-31 |
| 321 | 1.2.5.3.1.97 | WP1 meetings 97 | manual | 1d | 2024-02-07 | 2024-02-07 | start no earlier than 2024-02-07 |
| 322 | 1.2.5.3.1.98 | WP1 meetings 98 | manual | 1d | 2024-02-14 | 2024-02-14 | start no earlier than 2024-02-14 |
| 323 | 1.2.5.3.1.99 | WP1 meetings 99 | manual | 1d | 2024-02-21 | 2024-02-21 | start no earlier than 2024-02-21 |
| 324 | 1.2.5.3.1.100 | WP1 meetings 100 | manual | 1d | 2024-02-28 | 2024-02-28 | start no earlier than 2024-02-28 |
| 325 | 1.2.5.3.1.101 | WP1 meetings 101 | manual | 1d | 2024-03-06 | 2024-03-06 | start no earlier than 2024-03-06 |
| 326 | 1.2.5.3.1.102 | WP1 meetings 102 | manual | 1d | 2024-03-13 | 2024-03-13 | start no earlier than 2024-03-13 |
| 327 | 1.2.5.3.1.103 | WP1 meetings 103 | manual | 1d | 2024-03-20 | 2024-03-20 | start no earlier than 2024-03-20 |
| 328 | 1.2.5.3.1.104 | WP1 meetings 104 | manual | 1d | 2024-03-27 | 2024-03-27 | start no earlier than 2024-03-27 |
| 329 | 1.2.5.3.1.105 | WP1 meetings 105 | manual | 1d | 2024-04-03 | 2024-04-03 | start no earlier than 2024-04-03 |
| 330 | 1.2.5.3.1.106 | WP1 meetings 106 | manual | 1d | 2024-04-10 | 2024-04-10 | start no earlier than 2024-04-10 |
| 331 | 1.2.5.3.1.107 | WP1 meetings 107 | manual | 1d | 2024-04-17 | 2024-04-17 | start no earlier than 2024-04-17 |
| 332 | 1.2.5.3.1.108 | WP1 meetings 108 | manual | 1d | 2024-04-24 | 2024-04-24 | start no earlier than 2024-04-24 |
| 333 | 1.2.5.3.1.109 | WP1 meetings 109 | manual | 1d | 2024-05-01 | 2024-05-01 | start no earlier than 2024-05-01 |
| 334 | 1.2.5.3.1.110 | WP1 meetings 110 | manual | 1d | 2024-05-08 | 2024-05-08 | start no earlier than 2024-05-08 |
| 335 | 1.2.5.3.1.111 | WP1 meetings 111 | manual | 1d | 2024-05-15 | 2024-05-15 | start no earlier than 2024-05-15 |
| 336 | 1.2.5.3.1.112 | WP1 meetings 112 | manual | 1d | 2024-05-22 | 2024-05-22 | start no earlier than 2024-05-22 |
| 337 | 1.2.5.3.1.113 | WP1 meetings 113 | manual | 1d | 2024-05-29 | 2024-05-29 | start no earlier than 2024-05-29 |
| 338 | 1.2.5.3.1.114 | WP1 meetings 114 | manual | 1d | 2024-06-05 | 2024-06-05 | start no earlier than 2024-06-05 |
| 339 | 1.2.5.3.1.115 | WP1 meetings 115 | manual | 1d | 2024-06-12 | 2024-06-12 | start no earlier than 2024-06-12 |
| 340 | 1.2.5.3.1.116 | WP1 meetings 116 | manual | 1d | 2024-06-19 | 2024-06-19 | start no earlier than 2024-06-19 |
| 341 | 1.2.5.3.1.117 | WP1 meetings 117 | manual | 1d | 2024-06-26 | 2024-06-26 | start no earlier than 2024-06-26 |
| 342 | 1.2.5.3.1.118 | WP1 meetings 118 | manual | 1d | 2024-07-03 | 2024-07-03 | start no earlier than 2024-07-03 |
| 343 | 1.2.5.3.1.119 | WP1 meetings 119 | manual | 1d | 2024-07-10 | 2024-07-10 | start no earlier than 2024-07-10 |
| 344 | 1.2.5.3.1.120 | WP1 meetings 120 | manual | 1d | 2024-07-17 | 2024-07-17 | start no earlier than 2024-07-17 |
| 345 | 1.2.5.3.1.121 | WP1 meetings 121 | manual | 1d | 2024-07-24 | 2024-07-24 | start no earlier than 2024-07-24 |
| 346 | 1.2.5.3.1.122 | WP1 meetings 122 | manual | 1d | 2024-07-31 | 2024-07-31 | start no earlier than 2024-07-31 |
| 347 | 1.2.5.3.1.123 | WP1 meetings 123 | manual | 1d | 2024-08-07 | 2024-08-07 | start no earlier than 2024-08-07 |
| 348 | 1.2.5.3.1.124 | WP1 meetings 124 | manual | 1d | 2024-08-14 | 2024-08-14 | start no earlier than 2024-08-14 |
| 349 | 1.2.5.3.1.125 | WP1 meetings 125 | manual | 1d | 2024-08-21 | 2024-08-21 | start no earlier than 2024-08-21 |
| 350 | 1.2.5.3.1.126 | WP1 meetings 126 | manual | 1d | 2024-08-28 | 2024-08-28 | start no earlier than 2024-08-28 |
| 351 | 1.2.5.3.1.127 | WP1 meetings 127 | manual | 1d | 2024-09-04 | 2024-09-04 | start no earlier than 2024-09-04 |
| 352 | 1.2.5.3.1.128 | WP1 meetings 128 | manual | 1d | 2024-09-11 | 2024-09-11 | start no earlier than 2024-09-11 |
| 353 | 1.2.5.3.1.129 | WP1 meetings 129 | manual | 1d | 2024-09-18 | 2024-09-18 | start no earlier than 2024-09-18 |
| 354 | 1.2.5.3.1.130 | WP1 meetings 130 | manual | 1d | 2024-09-25 | 2024-09-25 | start no earlier than 2024-09-25 |
| 355 | 1.2.5.3.1.131 | WP1 meetings 131 | manual | 1d | 2024-10-02 | 2024-10-02 | start no earlier than 2024-10-02 |
| 356 | 1.2.5.3.1.132 | WP1 meetings 132 | manual | 1d | 2024-10-09 | 2024-10-09 | start no earlier than 2024-10-09 |
| 357 | 1.2.5.3.1.133 | WP1 meetings 133 | manual | 1d | 2024-10-16 | 2024-10-16 | start no earlier than 2024-10-16 |
| 358 | 1.2.5.3.1.134 | WP1 meetings 134 | manual | 1d | 2024-10-23 | 2024-10-23 | start no earlier than 2024-10-23 |
| 359 | 1.2.5.3.1.135 | WP1 meetings 135 | manual | 1d | 2024-10-30 | 2024-10-30 | start no earlier than 2024-10-30 |
| 360 | 1.2.5.3.1.136 | WP1 meetings 136 | manual | 1d | 2024-11-06 | 2024-11-06 | start no earlier than 2024-11-06 |
| 361 | 1.2.5.3.1.137 | WP1 meetings 137 | manual | 1d | 2024-11-13 | 2024-11-13 | start no earlier than 2024-11-13 |
| 362 | 1.2.5.3.1.138 | WP1 meetings 138 | manual | 1d | 2024-11-20 | 2024-11-20 | start no earlier than 2024-11-20 |

| ID | WBS | Task | Type | Duration | Start | Finish | Constraint |
| --- | --- | --- | --- | --- | --- | --- | --- |
| 363 | 1.2.5.3.1.139 | WP1 meetings 139 | manual | 1d | 2024-11-27 | 2024-11-27 | start no earlier than 2024-11-27 |
| 364 | 1.2.5.3.1.140 | WP1 meetings 140 | manual | 1d | 2024-12-04 | 2024-12-04 | start no earlier than 2024-12-04 |
| 365 | 1.2.5.3.1.141 | WP1 meetings 141 | manual | 1d | 2024-12-11 | 2024-12-11 | start no earlier than 2024-12-11 |
| 366 | 1.2.5.3.1.142 | WP1 meetings 142 | manual | 1d | 2024-12-18 | 2024-12-18 | start no earlier than 2024-12-18 |
| 367 | 1.2.5.3.1.143 | WP1 meetings 143 | manual | 1d | 2024-12-25 | 2024-12-25 | start no earlier than 2024-12-25 |
| 368 | 1.2.5.3.1.144 | WP1 meetings 144 | manual | 1d | 2025-01-01 | 2025-01-01 | start no earlier than 2025-01-01 |
| 369 | 1.2.5.3.1.145 | WP1 meetings 145 | manual | 1d | 2025-01-08 | 2025-01-08 | start no earlier than 2025-01-08 |
| 370 | 1.2.5.3.1.146 | WP1 meetings 146 | manual | 1d | 2025-01-15 | 2025-01-15 | start no earlier than 2025-01-15 |
| 371 | 1.2.5.3.1.147 | WP1 meetings 147 | manual | 1d | 2025-01-22 | 2025-01-22 | start no earlier than 2025-01-22 |
| 372 | 1.2.5.3.1.148 | WP1 meetings 148 | manual | 1d | 2025-01-29 | 2025-01-29 | start no earlier than 2025-01-29 |
| 373 | 1.2.5.3.1.149 | WP1 meetings 149 | manual | 1d | 2025-02-05 | 2025-02-05 | start no earlier than 2025-02-05 |
| 374 | 1.2.5.3.1.150 | WP1 meetings 150 | manual | 1d | 2025-02-12 | 2025-02-12 | start no earlier than 2025-02-12 |
| 375 | 1.2.5.3.1.151 | WP1 meetings 151 | manual | 1d | 2025-02-19 | 2025-02-19 | start no earlier than 2025-02-19 |
| 376 | 1.2.5.3.1.152 | WP1 meetings 152 | manual | 1d | 2025-02-26 | 2025-02-26 | start no earlier than 2025-02-26 |
| 377 | 1.2.5.3.1.153 | WP1 meetings 153 | manual | 1d | 2025-03-05 | 2025-03-05 | start no earlier than 2025-03-05 |
| 378 | 1.2.5.3.1.154 | WP1 meetings 154 | manual | 1d | 2025-03-12 | 2025-03-12 | start no earlier than 2025-03-12 |
| 379 | 1.2.5.3.1.155 | WP1 meetings 155 | manual | 1d | 2025-03-19 | 2025-03-19 | start no earlier than 2025-03-19 |
| 380 | 1.2.5.3.1.156 | WP1 meetings 156 | manual | 1d | 2025-03-26 | 2025-03-26 | start no earlier than 2025-03-26 |
| 381 | 1.2.5.3.1.157 | WP1 meetings 157 | manual | 1d | 2025-04-02 | 2025-04-02 | start no earlier than 2025-04-02 |
| 382 | 1.2.5.3.1.158 | WP1 meetings 158 | manual | 1d | 2025-04-09 | 2025-04-09 | start no earlier than 2025-04-09 |
| 383 | 1.2.5.3.1.159 | WP1 meetings 159 | manual | 1d | 2025-04-16 | 2025-04-16 | start no earlier than 2025-04-16 |
| 384 | 1.2.5.3.1.160 | WP1 meetings 160 | manual | 1d | 2025-04-23 | 2025-04-23 | start no earlier than 2025-04-23 |
| 385 | 1.2.5.3.1.161 | WP1 meetings 161 | manual | 1d | 2025-04-30 | 2025-04-30 | start no earlier than 2025-04-30 |
| 386 | 1.2.5.3.1.162 | WP1 meetings 162 | manual | 1d | 2025-05-07 | 2025-05-07 | start no earlier than 2025-05-07 |
| 387 | 1.2.5.3.1.163 | WP1 meetings 163 | manual | 1d | 2025-05-14 | 2025-05-14 | start no earlier than 2025-05-14 |
| 388 | 1.2.5.3.1.164 | WP1 meetings 164 | manual | 1d | 2025-05-21 | 2025-05-21 | start no earlier than 2025-05-21 |
| 389 | 1.2.5.3.1.165 | WP1 meetings 165 | manual | 1d | 2025-05-28 | 2025-05-28 | start no earlier than 2025-05-28 |
| 390 | 1.2.5.3.1.166 | WP1 meetings 166 | manual | 1d | 2025-06-04 | 2025-06-04 | start no earlier than 2025-06-04 |
| 391 | 1.2.5.3.1.167 | WP1 meetings 167 | manual | 1d | 2025-06-11 | 2025-06-11 | start no earlier than 2025-06-11 |
| 392 | 1.2.5.3.1.168 | WP1 meetings 168 | manual | 1d | 2025-06-18 | 2025-06-18 | start no earlier than 2025-06-18 |
| 393 | 1.2.5.3.1.169 | WP1 meetings 169 | manual | 1d | 2025-06-25 | 2025-06-25 | start no earlier than 2025-06-25 |
| 394 | 1.2.5.3.1.170 | WP1 meetings 170 | manual | 1d | 2025-07-02 | 2025-07-02 | start no earlier than 2025-07-02 |
| 395 | 1.2.5.3.1.171 | WP1 meetings 171 | manual | 1d | 2025-07-09 | 2025-07-09 | start no earlier than 2025-07-09 |
| 396 | 1.2.5.3.1.172 | WP1 meetings 172 | manual | 1d | 2025-07-16 | 2025-07-16 | start no earlier than 2025-07-16 |
| 397 | 1.2.5.3.1.173 | WP1 meetings 173 | manual | 1d | 2025-07-23 | 2025-07-23 | start no earlier than 2025-07-23 |
| 398 | 1.2.5.3.1.174 | WP1 meetings 174 | manual | 1d | 2025-07-30 | 2025-07-30 | start no earlier than 2025-07-30 |
| 399 | 1.2.5.3.1.175 | WP1 meetings 175 | manual | 1d | 2025-08-06 | 2025-08-06 | start no earlier than 2025-08-06 |
| 400 | 1.2.5.3.1.176 | WP1 meetings 176 | manual | 1d | 2025-08-13 | 2025-08-13 | start no earlier than 2025-08-13 |
| 401 | 1.2.5.3.1.177 | WP1 meetings 177 | manual | 1d | 2025-08-20 | 2025-08-20 | start no earlier than 2025-08-20 |
| 402 | 1.2.5.3.1.178 | WP1 meetings 178 | manual | 1d | 2025-08-27 | 2025-08-27 | start no earlier than 2025-08-27 |
| 403 | 1.2.5.3.1.179 | WP1 meetings 179 | manual | 1d | 2025-09-03 | 2025-09-03 | start no earlier than 2025-09-03 |
| 404 | 1.2.5.3.1.180 | WP1 meetings 180 | manual | 1d | 2025-09-10 | 2025-09-10 | start no earlier than 2025-09-10 |
| 405 | 1.2.5.3.1.181 | WP1 meetings 181 | manual | 1d | 2025-09-17 | 2025-09-17 | start no earlier than 2025-09-17 |
| 406 | 1.2.5.3.1.182 | WP1 meetings 182 | manual | 1d | 2025-09-24 | 2025-09-24 | start no earlier than 2025-09-24 |
| 407 | 1.2.5.3.1.183 | WP1 meetings 183 | manual | 1d | 2025-10-01 | 2025-10-01 | start no earlier than 2025-10-01 |
| 408 | 1.2.5.3.1.184 | WP1 meetings 184 | manual | 1d | 2025-10-08 | 2025-10-08 | start no earlier than 2025-10-08 |
| 409 | 1.2.5.3.1.185 | WP1 meetings 185 | manual | 1d | 2025-10-15 | 2025-10-15 | start no earlier than 2025-10-15 |
| 410 | 1.2.5.3.1.186 | WP1 meetings 186 | manual | 1d | 2025-10-22 | 2025-10-22 | start no earlier than 2025-10-22 |
| 411 | 1.2.5.3.1.187 | WP1 meetings 187 | manual | 1d | 2025-10-29 | 2025-10-29 | start no earlier than 2025-10-29 |
| 412 | 1.2.5.3.1.188 | WP1 meetings 188 | manual | 1d | 2025-11-05 | 2025-11-05 | start no earlier than 2025-11-05 |
| 413 | 1.2.5.3.1.189 | WP1 meetings 189 | manual | 1d | 2025-11-12 | 2025-11-12 | start no earlier than 2025-11-12 |
| 414 | 1.2.5.3.1.190 | WP1 meetings 190 | manual | 1d | 2025-11-19 | 2025-11-19 | start no earlier than 2025-11-19 |
| 415 | 1.2.5.3.1.191 | WP1 meetings 191 | manual | 1d | 2025-11-26 | 2025-11-26 | start no earlier than 2025-11-26 |
| 416 | 1.2.5.3.1.192 | WP1 meetings 192 | manual | 1d | 2025-12-03 | 2025-12-03 | start no earlier than 2025-12-03 |
| 417 | 1.2.5.3.1.193 | WP1 meetings 193 | manual | 1d | 2025-12-10 | 2025-12-10 | start no earlier than 2025-12-10 |
| 418 | 1.2.5.3.1.194 | WP1 meetings 194 | manual | 1d | 2025-12-17 | 2025-12-17 | start no earlier than 2025-12-17 |
| 419 | 1.2.5.3.1.195 | WP1 meetings 195 | manual | 1d | 2025-12-24 | 2025-12-24 | start no earlier than 2025-12-24 |
| 420 | 1.2.5.3.1.196 | WP1 meetings 196 | manual | 1d | 2025-12-31 | 2025-12-31 | start no earlier than 2025-12-31 |
| 421 | 1.2.5.3.1.197 | WP1 meetings 197 | manual | 1d | 2026-01-07 | 2026-01-07 | start no earlier than 2026-01-07 |
| 422 | 1.2.5.3.1.198 | WP1 meetings 198 | manual | 1d | 2026-01-14 | 2026-01-14 | start no earlier than 2026-01-14 |
| 423 | 1.2.5.3.1.199 | WP1 meetings 199 | manual | 1d | 2026-01-21 | 2026-01-21 | start no earlier than 2026-01-21 |
| 424 | 1.2.5.3.1.200 | WP1 meetings 200 | manual | 1d | 2026-01-28 | 2026-01-28 | start no earlier than 2026-01-28 |
| 425 | 1.2.5.3.1.201 | WP1 meetings 201 | manual | 1d | 2026-02-04 | 2026-02-04 | start no earlier than 2026-02-04 |
| 426 | 1.2.5.3.1.202 | WP1 meetings 202 | manual | 1d | 2026-02-11 | 2026-02-11 | start no earlier than 2026-02-11 |
| 427 | 1.2.5.3.1.203 | WP1 meetings 203 | manual | 1d | 2026-02-18 | 2026-02-18 | start no earlier than 2026-02-18 |
| 428 | 1.2.5.3.1.204 | WP1 meetings 204 | manual | 1d | 2026-02-25 | 2026-02-25 | start no earlier than 2026-02-25 |
| 429 | 1.2.5.3.1.205 | WP1 meetings 205 | manual | 1d | 2026-03-04 | 2026-03-04 | start no earlier than 2026-03-04 |
| 430 | 1.2.5.3.1.206 | WP1 meetings 206 | manual | 1d | 2026-03-11 | 2026-03-11 | start no earlier than 2026-03-11 |
| 431 | 1.2.5.3.1.207 | WP1 meetings 207 | manual | 1d | 2026-03-18 | 2026-03-18 | start no earlier than 2026-03-18 |
| 432 | 1.2.5.3.1.208 | WP1 meetings 208 | manual | 1d | 2026-03-25 | 2026-03-25 | start no earlier than 2026-03-25 |

| ID | WBS | Task | Type | Duration | Start | Finish | Constraint |
| --- | --- | --- | --- | --- | --- | --- | --- |
| 433 | 1.2.5.3.1.209 | WP1 meetings 209 | manual | 1d | 2026-04-01 | 2026-04-01 | start no earlier than 2026-04-01 |
| 434 | 1.2.5.3.1.210 | WP1 meetings 210 | manual | 1d | 2026-04-08 | 2026-04-08 | start no earlier than 2026-04-08 |
| 435 | 1.2.5.3.1.211 | WP1 meetings 211 | manual | 1d | 2026-04-15 | 2026-04-15 | start no earlier than 2026-04-15 |
| 436 | 1.2.5.3.1.212 | WP1 meetings 212 | manual | 1d | 2026-04-22 | 2026-04-22 | start no earlier than 2026-04-22 |
| 437 | 1.2.5.3.1.213 | WP1 meetings 213 | manual | 1d | 2026-04-29 | 2026-04-29 | start no earlier than 2026-04-29 |
| 438 | 1.2.5.3.1.214 | WP1 meetings 214 | manual | 1d | 2026-05-06 | 2026-05-06 | start no earlier than 2026-05-06 |
| 439 | 1.2.5.3.1.215 | WP1 meetings 215 | manual | 1d | 2026-05-13 | 2026-05-13 | start no earlier than 2026-05-13 |
| 440 | 1.2.5.3.1.216 | WP1 meetings 216 | manual | 1d | 2026-05-20 | 2026-05-20 | start no earlier than 2026-05-20 |
| 441 | 1.2.5.3.1.217 | WP1 meetings 217 | manual | 1d | 2026-05-27 | 2026-05-27 | start no earlier than 2026-05-27 |
| 442 | 1.2.5.3.1.218 | WP1 meetings 218 | manual | 1d | 2026-06-03 | 2026-06-03 | start no earlier than 2026-06-03 |
| 443 | 1.2.5.3.1.219 | WP1 meetings 219 | manual | 1d | 2026-06-10 | 2026-06-10 | start no earlier than 2026-06-10 |
| 444 | 1.2.5.3.1.220 | WP1 meetings 220 | manual | 1d | 2026-06-17 | 2026-06-17 | start no earlier than 2026-06-17 |
| 445 | 1.2.5.3.1.221 | WP1 meetings 221 | manual | 1d | 2026-06-24 | 2026-06-24 | start no earlier than 2026-06-24 |
| 446 | 1.2.5.3.1.222 | WP1 meetings 222 | manual | 1d | 2026-07-01 | 2026-07-01 | start no earlier than 2026-07-01 |
| 447 | 1.2.5.3.1.223 | WP1 meetings 223 | manual | 1d | 2026-07-08 | 2026-07-08 | start no earlier than 2026-07-08 |
| 448 | 1.2.5.3.1.224 | WP1 meetings 224 | manual | 1d | 2026-07-15 | 2026-07-15 | start no earlier than 2026-07-15 |
| 449 | 1.2.5.3.1.225 | WP1 meetings 225 | manual | 1d | 2026-07-22 | 2026-07-22 | start no earlier than 2026-07-22 |
| 450 | 1.2.5.3.1.226 | WP1 meetings 226 | manual | 1d | 2026-07-29 | 2026-07-29 | start no earlier than 2026-07-29 |
| 451 | 1.2.5.3.1.227 | WP1 meetings 227 | manual | 1d | 2026-08-05 | 2026-08-05 | start no earlier than 2026-08-05 |
| 452 | 1.2.5.3.1.228 | WP1 meetings 228 | manual | 1d | 2026-08-12 | 2026-08-12 | start no earlier than 2026-08-12 |
| 453 | 1.2.5.3.1.229 | WP1 meetings 229 | manual | 1d | 2026-08-19 | 2026-08-19 | start no earlier than 2026-08-19 |
| 454 | 1.2.5.3.1.230 | WP1 meetings 230 | manual | 1d | 2026-08-26 | 2026-08-26 | start no earlier than 2026-08-26 |
| 455 | 1.2.5.3.1.231 | WP1 meetings 231 | manual | 1d | 2026-09-02 | 2026-09-02 | start no earlier than 2026-09-02 |
| 456 | 1.2.5.3.1.232 | WP1 meetings 232 | manual | 1d | 2026-09-09 | 2026-09-09 | start no earlier than 2026-09-09 |
| 457 | 1.2.5.3.1.233 | WP1 meetings 233 | manual | 1d | 2026-09-16 | 2026-09-16 | start no earlier than 2026-09-16 |
| 458 | 1.2.5.3.1.234 | WP1 meetings 234 | manual | 1d | 2026-09-23 | 2026-09-23 | start no earlier than 2026-09-23 |
| 459 | 1.2.5.3.1.235 | WP1 meetings 235 | manual | 1d | 2026-09-30 | 2026-09-30 | start no earlier than 2026-09-30 |
| 460 | 1.2.5.3.1.236 | WP1 meetings 236 | manual | 1d | 2026-10-07 | 2026-10-07 | start no earlier than 2026-10-07 |
| 461 | 1.2.5.3.1.237 | WP1 meetings 237 | manual | 1d | 2026-10-14 | 2026-10-14 | start no earlier than 2026-10-14 |
| 462 | 1.2.5.3.1.238 | WP1 meetings 238 | manual | 1d | 2026-10-21 | 2026-10-21 | start no earlier than 2026-10-21 |
| 463 | 1.2.5.3.1.239 | WP1 meetings 239 | manual | 1d | 2026-10-28 | 2026-10-28 | start no earlier than 2026-10-28 |
| 464 | 1.2.5.3.1.240 | WP1 meetings 240 | manual | 1d | 2026-11-04 | 2026-11-04 | start no earlier than 2026-11-04 |
| 465 | 1.2.5.3.1.241 | WP1 meetings 241 | manual | 1d | 2026-11-11 | 2026-11-11 | start no earlier than 2026-11-11 |
| 466 | 1.2.5.3.1.242 | WP1 meetings 242 | manual | 1d | 2026-11-18 | 2026-11-18 | start no earlier than 2026-11-18 |
| 467 | 1.2.5.3.1.243 | WP1 meetings 243 | manual | 1d | 2026-11-25 | 2026-11-25 | start no earlier than 2026-11-25 |
| 468 | 1.2.5.3.1.244 | WP1 meetings 244 | manual | 1d | 2026-12-02 | 2026-12-02 | start no earlier than 2026-12-02 |
| 469 | 1.2.5.3.1.245 | WP1 meetings 245 | manual | 1d | 2026-12-09 | 2026-12-09 | start no earlier than 2026-12-09 |
| 470 | 1.2.5.3.1.246 | WP1 meetings 246 | manual | 1d | 2026-12-16 | 2026-12-16 | start no earlier than 2026-12-16 |
| 471 | 1.2.5.3.1.247 | WP1 meetings 247 | manual | 1d | 2026-12-23 | 2026-12-23 | start no earlier than 2026-12-23 |
| 472 | 1.2.5.3.1.248 | WP1 meetings 248 | manual | 1d | 2026-12-30 | 2026-12-30 | start no earlier than 2026-12-30 |
| 473 | 1.2.5.3.1.249 | WP1 meetings 249 | manual | 1d | 2027-01-06 | 2027-01-06 | start no earlier than 2027-01-06 |
| 474 | 1.2.5.3.1.250 | WP1 meetings 250 | manual | 1d | 2027-01-13 | 2027-01-13 | start no earlier than 2027-01-13 |
| 475 | 1.2.5.3.1.251 | WP1 meetings 251 | manual | 1d | 2027-01-20 | 2027-01-20 | start no earlier than 2027-01-20 |
| 476 | 1.2.5.3.1.252 | WP1 meetings 252 | manual | 1d | 2027-01-27 | 2027-01-27 | start no earlier than 2027-01-27 |
| 477 | 1.2.5.3.1.253 | WP1 meetings 253 | manual | 1d | 2027-02-03 | 2027-02-03 | start no earlier than 2027-02-03 |
| 478 | 1.2.5.3.1.254 | WP1 meetings 254 | manual | 1d | 2027-02-10 | 2027-02-10 | start no earlier than 2027-02-10 |
| 479 | 1.2.5.3.1.255 | WP1 meetings 255 | manual | 1d | 2027-02-17 | 2027-02-17 | start no earlier than 2027-02-17 |
| 480 | 1.2.5.3.1.256 | WP1 meetings 256 | manual | 1d | 2027-02-24 | 2027-02-24 | start no earlier than 2027-02-24 |
| 481 | 1.2.5.3.1.257 | WP1 meetings 257 | manual | 1d | 2027-03-03 | 2027-03-03 | start no earlier than 2027-03-03 |
| 482 | 1.2.5.3.1.258 | WP1 meetings 258 | manual | 1d | 2027-03-10 | 2027-03-10 | start no earlier than 2027-03-10 |
| 483 | 1.2.5.3.1.259 | WP1 meetings 259 | manual | 1d | 2027-03-17 | 2027-03-17 | start no earlier than 2027-03-17 |
| 484 | 1.2.5.3.1.260 | WP1 meetings 260 | manual | 1d | 2027-03-24 | 2027-03-24 | start no earlier than 2027-03-24 |
| 485 | 1.2.5.3.1.261 | WP1 meetings 261 | manual | 1d | 2027-03-31 | 2027-03-31 | start no earlier than 2027-03-31 |

| ID | WBS | Task | Type | Duration | Start | Finish | Total slack | Constraint |
| --- | --- | --- | --- | --- | --- | --- | --- | --- |
| 486 | 1.2.5.3.2 | **Project Office admin focused meeting** |  | 1283d | 2022-04-10 | 2027-03-10 | 0d |  |
| 487 | 1.2.5.3.2.1 | Project Office admin focused meeting 1 | manual | 1d | 2022-04-10 | 2022-04-10 |  | start no earlier than 2022-04-10 |
| 488 | 1.2.5.3.2.2 | Project Office admin focused meeting 2 | manual | 1d | 2022-05-10 | 2022-05-10 |  | start no earlier than 2022-05-10 |
| 489 | 1.2.5.3.2.3 | Project Office admin focused meeting 3 | manual | 1d | 2022-06-10 | 2022-06-10 |  | start no earlier than 2022-06-10 |
| 490 | 1.2.5.3.2.4 | Project Office admin focused meeting 4 | manual | 1d | 2022-07-10 | 2022-07-10 |  | start no earlier than 2022-07-10 |
| 491 | 1.2.5.3.2.5 | Project Office admin focused meeting 5 | manual | 1d | 2022-08-10 | 2022-08-10 |  | start no earlier than 2022-08-10 |
| 492 | 1.2.5.3.2.6 | Project Office admin focused meeting 6 | manual | 1d | 2022-09-10 | 2022-09-10 |  | start no earlier than 2022-09-10 |
| 493 | 1.2.5.3.2.7 | Project Office admin focused meeting 7 | manual | 1d | 2022-10-10 | 2022-10-10 |  | start no earlier than 2022-10-10 |
| 494 | 1.2.5.3.2.8 | Project Office admin focused meeting 8 | manual | 1d | 2022-11-10 | 2022-11-10 |  | start no earlier than 2022-11-10 |
| 495 | 1.2.5.3.2.9 | Project Office admin focused meeting 9 | manual | 1d | 2022-12-10 | 2022-12-10 |  | start no earlier than 2022-12-10 |
| 496 | 1.2.5.3.2.10 | Project Office admin focused meeting 10 | manual | 1d | 2023-01-10 | 2023-01-10 |  | start no earlier than 2023-01-10 |
| 497 | 1.2.5.3.2.11 | Project Office admin focused meeting 11 | manual | 1d | 2023-02-10 | 2023-02-10 |  | start no earlier than 2023-02-10 |
| 498 | 1.2.5.3.2.12 | Project Office admin focused meeting 12 | manual | 1d | 2023-03-10 | 2023-03-10 |  | start no earlier than 2023-03-10 |
| 499 | 1.2.5.3.2.13 | Project Office admin focused meeting 13 | manual | 1d | 2023-04-10 | 2023-04-10 |  | start no earlier than 2023-04-10 |
| 500 | 1.2.5.3.2.14 | Project Office admin focused meeting 14 | manual | 1d | 2023-05-10 | 2023-05-10 |  | start no earlier than 2023-05-10 |
| 501 | 1.2.5.3.2.15 | Project Office admin focused meeting 15 | manual | 1d | 2023-06-10 | 2023-06-10 |  | start no earlier than 2023-06-10 |
| 502 | 1.2.5.3.2.16 | Project Office admin focused meeting 16 | manual | 1d | 2023-07-10 | 2023-07-10 |  | start no earlier than 2023-07-10 |
| 503 | 1.2.5.3.2.17 | Project Office admin focused meeting 17 | manual | 1d | 2023-08-10 | 2023-08-10 |  | start no earlier than 2023-08-10 |
| 504 | 1.2.5.3.2.18 | Project Office admin focused meeting 18 | manual | 1d | 2023-09-10 | 2023-09-10 |  | start no earlier than 2023-09-10 |
| 505 | 1.2.5.3.2.19 | Project Office admin focused meeting 19 | manual | 1d | 2023-10-10 | 2023-10-10 |  | start no earlier than 2023-10-10 |
| 506 | 1.2.5.3.2.20 | Project Office admin focused meeting 20 | manual | 1d | 2023-11-10 | 2023-11-10 |  | start no earlier than 2023-11-10 |
| 507 | 1.2.5.3.2.21 | Project Office admin focused meeting 21 | manual | 1d | 2023-12-10 | 2023-12-10 |  | start no earlier than 2023-12-10 |
| 508 | 1.2.5.3.2.22 | Project Office admin focused meeting 22 | manual | 1d | 2024-01-10 | 2024-01-10 |  | start no earlier than 2024-01-10 |
| 509 | 1.2.5.3.2.23 | Project Office admin focused meeting 23 | manual | 1d | 2024-02-10 | 2024-02-10 |  | start no earlier than 2024-02-10 |
| 510 | 1.2.5.3.2.24 | Project Office admin focused meeting 24 | manual | 1d | 2024-03-10 | 2024-03-10 |  | start no earlier than 2024-03-10 |
| 511 | 1.2.5.3.2.25 | Project Office admin focused meeting 25 | manual | 1d | 2024-04-10 | 2024-04-10 |  | start no earlier than 2024-04-10 |
| 512 | 1.2.5.3.2.26 | Project Office admin focused meeting 26 | manual | 1d | 2024-05-10 | 2024-05-10 |  | start no earlier than 2024-05-10 |
| 513 | 1.2.5.3.2.27 | Project Office admin focused meeting 27 | manual | 1d | 2024-06-10 | 2024-06-10 |  | start no earlier than 2024-06-10 |
| 514 | 1.2.5.3.2.28 | Project Office admin focused meeting 28 | manual | 1d | 2024-07-10 | 2024-07-10 |  | start no earlier than 2024-07-10 |
| 515 | 1.2.5.3.2.29 | Project Office admin focused meeting 29 | manual | 1d | 2024-08-10 | 2024-08-10 |  | start no earlier than 2024-08-10 |
| 516 | 1.2.5.3.2.30 | Project Office admin focused meeting 30 | manual | 1d | 2024-09-10 | 2024-09-10 |  | start no earlier than 2024-09-10 |
| 517 | 1.2.5.3.2.31 | Project Office admin focused meeting 31 | manual | 1d | 2024-10-10 | 2024-10-10 |  | start no earlier than 2024-10-10 |
| 518 | 1.2.5.3.2.32 | Project Office admin focused meeting 32 | manual | 1d | 2024-11-10 | 2024-11-10 |  | start no earlier than 2024-11-10 |
| 519 | 1.2.5.3.2.33 | Project Office admin focused meeting 33 | manual | 1d | 2024-12-10 | 2024-12-10 |  | start no earlier than 2024-12-10 |
| 520 | 1.2.5.3.2.34 | Project Office admin focused meeting 34 | manual | 1d | 2025-01-10 | 2025-01-10 |  | start no earlier than 2025-01-10 |
| 521 | 1.2.5.3.2.35 | Project Office admin focused meeting 35 | manual | 1d | 2025-02-10 | 2025-02-10 |  | start no earlier than 2025-02-10 |
| 522 | 1.2.5.3.2.36 | Project Office admin focused meeting 36 | manual | 1d | 2025-03-10 | 2025-03-10 |  | start no earlier than 2025-03-10 |
| 523 | 1.2.5.3.2.37 | Project Office admin focused meeting 37 | manual | 1d | 2025-04-10 | 2025-04-10 |  | start no earlier than 2025-04-10 |
| 524 | 1.2.5.3.2.38 | Project Office admin focused meeting 38 | manual | 1d | 2025-05-10 | 2025-05-10 |  | start no earlier than 2025-05-10 |
| 525 | 1.2.5.3.2.39 | Project Office admin focused meeting 39 | manual | 1d | 2025-06-10 | 2025-06-10 |  | start no earlier than 2025-06-10 |
| 526 | 1.2.5.3.2.40 | Project Office admin focused meeting 40 | manual | 1d | 2025-07-10 | 2025-07-10 |  | start no earlier than 2025-07-10 |
| 527 | 1.2.5.3.2.41 | Project Office admin focused meeting 41 | manual | 1d | 2025-08-10 | 2025-08-10 |  | start no earlier than 2025-08-10 |
| 528 | 1.2.5.3.2.42 | Project Office admin focused meeting 42 | manual | 1d | 2025-09-10 | 2025-09-10 |  | start no earlier than 2025-09-10 |
| 529 | 1.2.5.3.2.43 | Project Office admin focused meeting 43 | manual | 1d | 2025-10-10 | 2025-10-10 |  | start no earlier than 2025-10-10 |
| 530 | 1.2.5.3.2.44 | Project Office admin focused meeting 44 | manual | 1d | 2025-11-10 | 2025-11-10 |  | start no earlier than 2025-11-10 |
| 531 | 1.2.5.3.2.45 | Project Office admin focused meeting 45 | manual | 1d | 2025-12-10 | 2025-12-10 |  | start no earlier than 2025-12-10 |
| 532 | 1.2.5.3.2.46 | Project Office admin focused meeting 46 | manual | 1d | 2026-01-10 | 2026-01-10 |  | start no earlier than 2026-01-10 |
| 533 | 1.2.5.3.2.47 | Project Office admin focused meeting 47 | manual | 1d | 2026-02-10 | 2026-02-10 |  | start no earlier than 2026-02-10 |
| 534 | 1.2.5.3.2.48 | Project Office admin focused meeting 48 | manual | 1d | 2026-03-10 | 2026-03-10 |  | start no earlier than 2026-03-10 |
| 535 | 1.2.5.3.2.49 | Project Office admin focused meeting 49 | manual | 1d | 2026-04-10 | 2026-04-10 |  | start no earlier than 2026-04-10 |
| 536 | 1.2.5.3.2.50 | Project Office admin focused meeting 50 | manual | 1d | 2026-05-10 | 2026-05-10 |  | start no earlier than 2026-05-10 |
| 537 | 1.2.5.3.2.51 | Project Office admin focused meeting 51 | manual | 1d | 2026-06-10 | 2026-06-10 |  | start no earlier than 2026-06-10 |
| 538 | 1.2.5.3.2.52 | Project Office admin focused meeting 52 | manual | 1d | 2026-07-10 | 2026-07-10 |  | start no earlier than 2026-07-10 |
| 539 | 1.2.5.3.2.53 | Project Office admin focused meeting 53 | manual | 1d | 2026-08-10 | 2026-08-10 |  | start no earlier than 2026-08-10 |
| 540 | 1.2.5.3.2.54 | Project Office admin focused meeting 54 | manual | 1d | 2026-09-10 | 2026-09-10 |  | start no earlier than 2026-09-10 |
| 541 | 1.2.5.3.2.55 | Project Office admin focused meeting 55 | manual | 1d | 2026-10-10 | 2026-10-10 |  | start no earlier than 2026-10-10 |
| 542 | 1.2.5.3.2.56 | Project Office admin focused meeting 56 | manual | 1d | 2026-11-10 | 2026-11-10 |  | start no earlier than 2026-11-10 |
| 543 | 1.2.5.3.2.57 | Project Office admin focused meeting 57 | manual | 1d | 2026-12-10 | 2026-12-10 |  | start no earlier than 2026-12-10 |
| 544 | 1.2.5.3.2.58 | Project Office admin focused meeting 58 | manual | 1d | 2027-01-10 | 2027-01-10 |  | start no earlier than 2027-01-10 |
| 545 | 1.2.5.3.2.59 | Project Office admin focused meeting 59 | manual | 1d | 2027-02-10 | 2027-02-10 |  | start no earlier than 2027-02-10 |
| 546 | 1.2.5.3.2.60 | Project Office admin focused meeting 60 | manual | 1d | 2027-03-10 | 2027-03-10 |  | start no earlier than 2027-03-10 |

| ID | WBS | Task | Type | Duration | Start | Finish | Total slack | Constraint |
| --- | --- | --- | --- | --- | --- | --- | --- | --- |
| 547 | 1.2.5.3.3 | **Insitute board meetings** |  | 1477d | 2021-08-03 | 2027-03-31 | 0d |  |
| 548 | 1.2.5.3.3.1 | insitute board meetings 1 | manual | 1d | 2021-08-03 | 2021-08-03 |  | start no earlier than 2021-08-03 |
| 549 | 1.2.5.3.3.2 | insitute board meetings 2 | manual | 1d | 2021-10-03 | 2021-10-03 |  | start no earlier than 2021-10-03 |
| 550 | 1.2.5.3.3.3 | insitute board meetings 3 | manual | 1d | 2021-12-03 | 2021-12-03 |  | start no earlier than 2021-12-03 |
| 551 | 1.2.5.3.3.4 | insitute board meetings 4 | manual | 1d | 2022-02-03 | 2022-02-03 |  | start no earlier than 2022-02-03 |
| 552 | 1.2.5.3.3.5 | insitute board meetings 5 | manual | 1d | 2022-04-03 | 2022-04-03 |  | start no earlier than 2022-04-03 |
| 553 | 1.2.5.3.3.6 | insitute board meetings 6 | manual | 1d | 2022-06-03 | 2022-06-03 |  | start no earlier than 2022-06-03 |
| 554 | 1.2.5.3.3.7 | insitute board meetings 7 | manual | 1d | 2022-08-03 | 2022-08-03 |  | start no earlier than 2022-08-03 |
| 555 | 1.2.5.3.3.8 | insitute board meetings 8 | manual | 1d | 2022-10-03 | 2022-10-03 |  | start no earlier than 2022-10-03 |
| 556 | 1.2.5.3.3.9 | insitute board meetings 9 | manual | 1d | 2022-12-03 | 2022-12-03 |  | start no earlier than 2022-12-03 |
| 557 | 1.2.5.3.3.10 | insitute board meetings 10 | manual | 1d | 2023-02-03 | 2023-02-03 |  | start no earlier than 2023-02-03 |
| 558 | 1.2.5.3.3.11 | insitute board meetings 11 | manual | 1d | 2023-04-03 | 2023-04-03 |  | start no earlier than 2023-04-03 |
| 559 | 1.2.5.3.3.12 | insitute board meetings 12 | manual | 1d | 2023-06-03 | 2023-06-03 |  | start no earlier than 2023-06-03 |
| 560 | 1.2.5.3.3.13 | insitute board meetings 13 | manual | 1d | 2023-08-03 | 2023-08-03 |  | start no earlier than 2023-08-03 |
| 561 | 1.2.5.3.3.14 | insitute board meetings 14 | manual | 1d | 2023-10-03 | 2023-10-03 |  | start no earlier than 2023-10-03 |
| 562 | 1.2.5.3.3.15 | insitute board meetings 15 | manual | 1d | 2023-12-03 | 2023-12-03 |  | start no earlier than 2023-12-03 |
| 563 | 1.2.5.3.3.16 | insitute board meetings 16 | manual | 1d | 2024-02-03 | 2024-02-03 |  | start no earlier than 2024-02-03 |
| 564 | 1.2.5.3.3.17 | insitute board meetings 17 | manual | 1d | 2024-04-03 | 2024-04-03 |  | start no earlier than 2024-04-03 |
| 565 | 1.2.5.3.3.18 | insitute board meetings 18 | manual | 1d | 2024-06-03 | 2024-06-03 |  | start no earlier than 2024-06-03 |
| 566 | 1.2.5.3.3.19 | insitute board meetings 19 | manual | 1d | 2024-08-03 | 2024-08-03 |  | start no earlier than 2024-08-03 |
| 567 | 1.2.5.3.3.20 | insitute board meetings 20 | manual | 1d | 2024-10-03 | 2024-10-03 |  | start no earlier than 2024-10-03 |
| 568 | 1.2.5.3.3.21 | insitute board meetings 21 | manual | 1d | 2024-12-03 | 2024-12-03 |  | start no earlier than 2024-12-03 |
| 569 | 1.2.5.3.3.22 | insitute board meetings 22 | manual | 1d | 2025-02-03 | 2025-02-03 |  | start no earlier than 2025-02-03 |
| 570 | 1.2.5.3.3.23 | insitute board meetings 23 | manual | 1d | 2025-04-03 | 2025-04-03 |  | start no earlier than 2025-04-03 |
| 571 | 1.2.5.3.3.24 | insitute board meetings 24 | manual | 1d | 2025-06-03 | 2025-06-03 |  | start no earlier than 2025-06-03 |
| 572 | 1.2.5.3.3.25 | insitute board meetings 25 | manual | 1d | 2025-08-03 | 2025-08-03 |  | start no earlier than 2025-08-03 |
| 573 | 1.2.5.3.3.26 | insitute board meetings 26 | manual | 1d | 2025-10-03 | 2025-10-03 |  | start no earlier than 2025-10-03 |
| 574 | 1.2.5.3.3.27 | insitute board meetings 27 | manual | 1d | 2025-12-03 | 2025-12-03 |  | start no earlier than 2025-12-03 |
| 575 | 1.2.5.3.3.28 | insitute board meetings 28 | manual | 1d | 2026-02-03 | 2026-02-03 |  | start no earlier than 2026-02-03 |
| 576 | 1.2.5.3.3.29 | insitute board meetings 29 | manual | 1d | 2026-04-03 | 2026-04-03 |  | start no earlier than 2026-04-03 |
| 577 | 1.2.5.3.3.30 | insitute board meetings 30 | manual | 1d | 2026-06-03 | 2026-06-03 |  | start no earlier than 2026-06-03 |
| 578 | 1.2.5.3.3.31 | insitute board meetings 31 | manual | 1d | 2026-08-03 | 2026-08-03 |  | start no earlier than 2026-08-03 |
| 579 | 1.2.5.3.3.32 | insitute board meetings 32 | manual | 1d | 2026-10-03 | 2026-10-03 |  | start no earlier than 2026-10-03 |
| 580 | 1.2.5.3.3.33 | insitute board meetings 33 | manual | 1d | 2026-12-03 | 2026-12-03 |  | start no earlier than 2026-12-03 |
| 581 | 1.2.5.3.3.34 | insitute board meetings 34 | manual | 1d | 2027-02-03 | 2027-02-03 |  | start no earlier than 2027-02-03 |

| ID | WBS | Task | Type | Duration | Start | Finish | Total slack | Constraint |
| --- | --- | --- | --- | --- | --- | --- | --- | --- |
| 582 | 1.2.5.3.3.35 | **STFC Project Risk Committee** |  | 1286d | 2022-04-27 | 2027-03-31 | 0d |  |
| 583 | 1.2.5.3.3.35.1 | STFC Project Risk Committee 1 | manual | 1d | 2022-04-27 | 2022-04-27 |  | start no earlier than 2022-04-27 |
| 584 | 1.2.5.3.3.35.2 | STFC Project Risk Committee 2 | manual | 1d | 2022-05-25 | 2022-05-25 |  | start no earlier than 2022-05-25 |
| 585 | 1.2.5.3.3.35.3 | STFC Project Risk Committee 3 | manual | 1d | 2022-06-29 | 2022-06-29 |  | start no earlier than 2022-06-29 |
| 586 | 1.2.5.3.3.35.4 | STFC Project Risk Committee 4 | manual | 1d | 2022-07-27 | 2022-07-27 |  | start no earlier than 2022-07-27 |
| 587 | 1.2.5.3.3.35.5 | STFC Project Risk Committee 5 | manual | 1d | 2022-08-31 | 2022-08-31 |  | start no earlier than 2022-08-31 |
| 588 | 1.2.5.3.3.35.6 | STFC Project Risk Committee 6 | manual | 1d | 2022-09-28 | 2022-09-28 |  | start no earlier than 2022-09-28 |
| 589 | 1.2.5.3.3.35.7 | STFC Project Risk Committee 7 | manual | 1d | 2022-10-26 | 2022-10-26 |  | start no earlier than 2022-10-26 |
| 590 | 1.2.5.3.3.35.8 | STFC Project Risk Committee 8 | manual | 1d | 2022-11-30 | 2022-11-30 |  | start no earlier than 2022-11-30 |
| 591 | 1.2.5.3.3.35.9 | STFC Project Risk Committee 9 | manual | 1d | 2022-12-28 | 2022-12-28 |  | start no earlier than 2022-12-28 |
| 592 | 1.2.5.3.3.35.10 | STFC Project Risk Committee 10 | manual | 1d | 2023-01-25 | 2023-01-25 |  | start no earlier than 2023-01-25 |
| 593 | 1.2.5.3.3.35.11 | STFC Project Risk Committee 11 | manual | 1d | 2023-02-22 | 2023-02-22 |  | start no earlier than 2023-02-22 |
| 594 | 1.2.5.3.3.35.12 | STFC Project Risk Committee 12 | manual | 1d | 2023-03-29 | 2023-03-29 |  | start no earlier than 2023-03-29 |
| 595 | 1.2.5.3.3.35.13 | STFC Project Risk Committee 13 | manual | 1d | 2023-04-26 | 2023-04-26 |  | start no earlier than 2023-04-26 |
| 596 | 1.2.5.3.3.35.14 | STFC Project Risk Committee 14 | manual | 1d | 2023-05-31 | 2023-05-31 |  | start no earlier than 2023-05-31 |
| 597 | 1.2.5.3.3.35.15 | STFC Project Risk Committee 15 | manual | 1d | 2023-06-28 | 2023-06-28 |  | start no earlier than 2023-06-28 |
| 598 | 1.2.5.3.3.35.16 | STFC Project Risk Committee 16 | manual | 1d | 2023-07-26 | 2023-07-26 |  | start no earlier than 2023-07-26 |
| 599 | 1.2.5.3.3.35.17 | STFC Project Risk Committee 17 | manual | 1d | 2023-08-30 | 2023-08-30 |  | start no earlier than 2023-08-30 |
| 600 | 1.2.5.3.3.35.18 | STFC Project Risk Committee 18 | manual | 1d | 2023-09-27 | 2023-09-27 |  | start no earlier than 2023-09-27 |
| 601 | 1.2.5.3.3.35.19 | STFC Project Risk Committee 19 | manual | 1d | 2023-10-25 | 2023-10-25 |  | start no earlier than 2023-10-25 |
| 602 | 1.2.5.3.3.35.20 | STFC Project Risk Committee 20 | manual | 1d | 2023-11-29 | 2023-11-29 |  | start no earlier than 2023-11-29 |
| 603 | 1.2.5.3.3.35.21 | STFC Project Risk Committee 21 | manual | 1d | 2023-12-27 | 2023-12-27 |  | start no earlier than 2023-12-27 |
| 604 | 1.2.5.3.3.35.22 | STFC Project Risk Committee 22 | manual | 1d | 2024-01-31 | 2024-01-31 |  | start no earlier than 2024-01-31 |
| 605 | 1.2.5.3.3.35.23 | STFC Project Risk Committee 23 | manual | 1d | 2024-02-28 | 2024-02-28 |  | start no earlier than 2024-02-28 |
| 606 | 1.2.5.3.3.35.24 | STFC Project Risk Committee 24 | manual | 1d | 2024-03-27 | 2024-03-27 |  | start no earlier than 2024-03-27 |
| 607 | 1.2.5.3.3.35.25 | STFC Project Risk Committee 25 | manual | 1d | 2024-04-24 | 2024-04-24 |  | start no earlier than 2024-04-24 |
| 608 | 1.2.5.3.3.35.26 | STFC Project Risk Committee 26 | manual | 1d | 2024-05-29 | 2024-05-29 |  | start no earlier than 2024-05-29 |
| 609 | 1.2.5.3.3.35.27 | STFC Project Risk Committee 27 | manual | 1d | 2024-06-26 | 2024-06-26 |  | start no earlier than 2024-06-26 |
| 610 | 1.2.5.3.3.35.28 | STFC Project Risk Committee 28 | manual | 1d | 2024-07-31 | 2024-07-31 |  | start no earlier than 2024-07-31 |
| 611 | 1.2.5.3.3.35.29 | STFC Project Risk Committee 29 | manual | 1d | 2024-08-28 | 2024-08-28 |  | start no earlier than 2024-08-28 |
| 612 | 1.2.5.3.3.35.30 | STFC Project Risk Committee 30 | manual | 1d | 2024-09-25 | 2024-09-25 |  | start no earlier than 2024-09-25 |
| 613 | 1.2.5.3.3.35.31 | STFC Project Risk Committee 31 | manual | 1d | 2024-10-30 | 2024-10-30 |  | start no earlier than 2024-10-30 |
| 614 | 1.2.5.3.3.35.32 | STFC Project Risk Committee 32 | manual | 1d | 2024-11-27 | 2024-11-27 |  | start no earlier than 2024-11-27 |
| 615 | 1.2.5.3.3.35.33 | STFC Project Risk Committee 33 | manual | 1d | 2024-12-25 | 2024-12-25 |  | start no earlier than 2024-12-25 |
| 616 | 1.2.5.3.3.35.34 | STFC Project Risk Committee 34 | manual | 1d | 2025-01-29 | 2025-01-29 |  | start no earlier than 2025-01-29 |
| 617 | 1.2.5.3.3.35.35 | STFC Project Risk Committee 35 | manual | 1d | 2025-02-26 | 2025-02-26 |  | start no earlier than 2025-02-26 |
| 618 | 1.2.5.3.3.35.36 | STFC Project Risk Committee 36 | manual | 1d | 2025-03-26 | 2025-03-26 |  | start no earlier than 2025-03-26 |
| 619 | 1.2.5.3.3.35.37 | STFC Project Risk Committee 37 | manual | 1d | 2025-04-30 | 2025-04-30 |  | start no earlier than 2025-04-30 |
| 620 | 1.2.5.3.3.35.38 | STFC Project Risk Committee 38 | manual | 1d | 2025-05-28 | 2025-05-28 |  | start no earlier than 2025-05-28 |
| 621 | 1.2.5.3.3.35.39 | STFC Project Risk Committee 39 | manual | 1d | 2025-06-25 | 2025-06-25 |  | start no earlier than 2025-06-25 |
| 622 | 1.2.5.3.3.35.40 | STFC Project Risk Committee 40 | manual | 1d | 2025-07-30 | 2025-07-30 |  | start no earlier than 2025-07-30 |
| 623 | 1.2.5.3.3.35.41 | STFC Project Risk Committee 41 | manual | 1d | 2025-08-27 | 2025-08-27 |  | start no earlier than 2025-08-27 |
| 624 | 1.2.5.3.3.35.42 | STFC Project Risk Committee 42 | manual | 1d | 2025-09-24 | 2025-09-24 |  | start no earlier than 2025-09-24 |
| 625 | 1.2.5.3.3.35.43 | STFC Project Risk Committee 43 | manual | 1d | 2025-10-29 | 2025-10-29 |  | start no earlier than 2025-10-29 |
| 626 | 1.2.5.3.3.35.44 | STFC Project Risk Committee 44 | manual | 1d | 2025-11-26 | 2025-11-26 |  | start no earlier than 2025-11-26 |
| 627 | 1.2.5.3.3.35.45 | STFC Project Risk Committee 45 | manual | 1d | 2025-12-31 | 2025-12-31 |  | start no earlier than 2025-12-31 |
| 628 | 1.2.5.3.3.35.46 | STFC Project Risk Committee 46 | manual | 1d | 2026-01-28 | 2026-01-28 |  | start no earlier than 2026-01-28 |
| 629 | 1.2.5.3.3.35.47 | STFC Project Risk Committee 47 | manual | 1d | 2026-02-25 | 2026-02-25 |  | start no earlier than 2026-02-25 |
| 630 | 1.2.5.3.3.35.48 | STFC Project Risk Committee 48 | manual | 1d | 2026-03-25 | 2026-03-25 |  | start no earlier than 2026-03-25 |
| 631 | 1.2.5.3.3.35.49 | STFC Project Risk Committee 49 | manual | 1d | 2026-04-29 | 2026-04-29 |  | start no earlier than 2026-04-29 |
| 632 | 1.2.5.3.3.35.50 | STFC Project Risk Committee 50 | manual | 1d | 2026-05-27 | 2026-05-27 |  | start no earlier than 2026-05-27 |
| 633 | 1.2.5.3.3.35.51 | STFC Project Risk Committee 51 | manual | 1d | 2026-06-24 | 2026-06-24 |  | start no earlier than 2026-06-24 |
| 634 | 1.2.5.3.3.35.52 | STFC Project Risk Committee 52 | manual | 1d | 2026-07-29 | 2026-07-29 |  | start no earlier than 2026-07-29 |
| 635 | 1.2.5.3.3.35.53 | STFC Project Risk Committee 53 | manual | 1d | 2026-08-26 | 2026-08-26 |  | start no earlier than 2026-08-26 |
| 636 | 1.2.5.3.3.35.54 | STFC Project Risk Committee 54 | manual | 1d | 2026-09-30 | 2026-09-30 |  | start no earlier than 2026-09-30 |
| 637 | 1.2.5.3.3.35.55 | STFC Project Risk Committee 55 | manual | 1d | 2026-10-28 | 2026-10-28 |  | start no earlier than 2026-10-28 |
| 638 | 1.2.5.3.3.35.56 | STFC Project Risk Committee 56 | manual | 1d | 2026-11-25 | 2026-11-25 |  | start no earlier than 2026-11-25 |
| 639 | 1.2.5.3.3.35.57 | STFC Project Risk Committee 57 | manual | 1d | 2026-12-30 | 2026-12-30 |  | start no earlier than 2026-12-30 |
| 640 | 1.2.5.3.3.35.58 | STFC Project Risk Committee 58 | manual | 1d | 2027-01-27 | 2027-01-27 |  | start no earlier than 2027-01-27 |
| 641 | 1.2.5.3.3.35.59 | STFC Project Risk Committee 59 | manual | 1d | 2027-02-24 | 2027-02-24 |  | start no earlier than 2027-02-24 |
| 642 | 1.2.5.3.3.35.60 | STFC Project Risk Committee 60 | manual | 1d | 2027-03-31 | 2027-03-31 |  | start no earlier than 2027-03-31 |
| 643 | 1.2.5.3.3.36 | LhARA Project Group | manual | 1d? | 2021-08-03 | 2021-08-03 |  |  |
| 644 | 1.2.5.3.3.37 | Deliverables- Reports to STFC | manual | 1d? | 2021-08-03 | 2021-08-03 |  |  |

| ID | WBS | Task | Type | Duration | Start | Finish | Total slack | Constraint |
| --- | --- | --- | --- | --- | --- | --- | --- | --- |
| 645 | 1.2.5.3.4 | **LhARA Collaboration Meetings** |  | 1304d? | 2022-04-01 | 2027-03-31 |  |  |
| 646 | 1.2.5.3.4.1 | **Collaboration meetings** |  | 1286d | 2022-04-05 | 2027-03-09 | 0d |  |
| 647 | 1.2.5.3.4.1.1 | Kick Off meeting | manual | 1d | 2022-04-05 | 2022-04-05 |  | start no earlier than 2022-04-05 |
| 648 | 1.2.5.3.4.1.2 | Collaboration meetings 2 | manual | 1d | 2022-08-02 | 2022-08-02 |  | start no earlier than 2022-08-02 |
| 649 | 1.2.5.3.4.1.3 | Collaboration meetings 3 | manual | 1d | 2022-12-06 | 2022-12-06 |  | start no earlier than 2022-12-06 |
| 650 | 1.2.5.3.4.1.4 | Collaboration meetings 4 | manual | 1d | 2023-04-04 | 2023-04-04 |  | start no earlier than 2023-04-04 |
| 651 | 1.2.5.3.4.1.5 | Collaboration meetings 5 | manual | 1d | 2023-08-01 | 2023-08-01 |  | start no earlier than 2023-08-01 |
| 652 | 1.2.5.3.4.1.6 | Collaboration meetings 6 | manual | 1d | 2023-12-05 | 2023-12-05 |  | start no earlier than 2023-12-05 |
| 653 | 1.2.5.3.4.1.7 | Collaboration meetings 7 | manual | 1d | 2024-04-02 | 2024-04-02 |  | start no earlier than 2024-04-02 |
| 654 | 1.2.5.3.4.1.8 | Collaboration meetings 8 | manual | 1d | 2024-08-06 | 2024-08-06 |  | start no earlier than 2024-08-06 |
| 655 | 1.2.5.3.4.1.9 | Collaboration meetings 9 | manual | 1d | 2024-12-03 | 2024-12-03 |  | start no earlier than 2024-12-03 |
| 656 | 1.2.5.3.4.1.10 | Collaboration meetings 10 | manual | 1d | 2025-04-01 | 2025-04-01 |  | start no earlier than 2025-04-01 |
| 657 | 1.2.5.3.4.1.11 | Collaboration meetings 11 | manual | 1d | 2025-08-05 | 2025-08-05 |  | start no earlier than 2025-08-05 |
| 658 | 1.2.5.3.4.1.12 | Collaboration meetings 12 | manual | 1d | 2025-12-02 | 2025-12-02 |  | start no earlier than 2025-12-02 |
| 659 | 1.2.5.3.4.1.13 | Collaboration meetings 13 | manual | 1d | 2026-04-07 | 2026-04-07 |  | start no earlier than 2026-04-07 |
| 660 | 1.2.5.3.4.1.14 | Collaboration meetings 14 | manual | 1d | 2026-08-04 | 2026-08-04 |  | start no earlier than 2026-08-04 |
| 661 | 1.2.5.3.4.1.15 | Collaboration meetings 15 | manual | 1d | 2026-12-01 | 2026-12-01 |  | start no earlier than 2026-12-01 |
| 662 | 1.2.5.3.4.1.16 | **Progress meetings (with each WP)** |  | 1281d | 2022-04-12 | 2027-03-09 | 0d |  |
| 663 | 1.2.5.3.4.1.16.1 | Progress meetings (with each WP) 1 | manual | 1d | 2022-04-12 | 2022-04-12 |  | start no earlier than 2022-04-12 |
| 664 | 1.2.5.3.4.1.16.2 | Progress meetings (with each WP) 2 | manual | 1d | 2022-05-10 | 2022-05-10 |  | start no earlier than 2022-05-10 |
| 665 | 1.2.5.3.4.1.16.3 | Progress meetings (with each WP) 3 | manual | 1d | 2022-06-14 | 2022-06-14 |  | start no earlier than 2022-06-14 |
| 666 | 1.2.5.3.4.1.16.4 | Progress meetings (with each WP) 4 | manual | 1d | 2022-07-12 | 2022-07-12 |  | start no earlier than 2022-07-12 |
| 667 | 1.2.5.3.4.1.16.5 | Progress meetings (with each WP) 5 | manual | 1d | 2022-08-09 | 2022-08-09 |  | start no earlier than 2022-08-09 |
| 668 | 1.2.5.3.4.1.16.6 | Progress meetings (with each WP) 6 | manual | 1d | 2022-09-13 | 2022-09-13 |  | start no earlier than 2022-09-13 |
| 669 | 1.2.5.3.4.1.16.7 | Progress meetings (with each WP) 7 | manual | 1d | 2022-10-11 | 2022-10-11 |  | start no earlier than 2022-10-11 |
| 670 | 1.2.5.3.4.1.16.8 | Progress meetings (with each WP) 8 | manual | 1d | 2022-11-08 | 2022-11-08 |  | start no earlier than 2022-11-08 |
| 671 | 1.2.5.3.4.1.16.9 | Progress meetings (with each WP) 9 | manual | 1d | 2022-12-13 | 2022-12-13 |  | start no earlier than 2022-12-13 |
| 672 | 1.2.5.3.4.1.16.10 | Progress meetings (with each WP) 10 | manual | 1d | 2023-01-10 | 2023-01-10 |  | start no earlier than 2023-01-10 |
| 673 | 1.2.5.3.4.1.16.11 | Progress meetings (with each WP) 11 | manual | 1d | 2023-02-14 | 2023-02-14 |  | start no earlier than 2023-02-14 |
| 674 | 1.2.5.3.4.1.16.12 | Progress meetings (with each WP) 12 | manual | 1d | 2023-03-14 | 2023-03-14 |  | start no earlier than 2023-03-14 |
| 675 | 1.2.5.3.4.1.16.13 | Progress meetings (with each WP) 13 | manual | 1d | 2023-04-11 | 2023-04-11 |  | start no earlier than 2023-04-11 |
| 676 | 1.2.5.3.4.1.16.14 | Progress meetings (with each WP) 14 | manual | 1d | 2023-05-09 | 2023-05-09 |  | start no earlier than 2023-05-09 |
| 677 | 1.2.5.3.4.1.16.15 | Progress meetings (with each WP) 15 | manual | 1d | 2023-06-13 | 2023-06-13 |  | start no earlier than 2023-06-13 |
| 678 | 1.2.5.3.4.1.16.16 | Progress meetings (with each WP) 16 | manual | 1d | 2023-07-11 | 2023-07-11 |  | start no earlier than 2023-07-11 |
| 679 | 1.2.5.3.4.1.16.17 | Progress meetings (with each WP) 17 | manual | 1d | 2023-08-08 | 2023-08-08 |  | start no earlier than 2023-08-08 |
| 680 | 1.2.5.3.4.1.16.18 | Progress meetings (with each WP) 18 | manual | 1d | 2023-09-12 | 2023-09-12 |  | start no earlier than 2023-09-12 |
| 681 | 1.2.5.3.4.1.16.19 | Progress meetings (with each WP) 19 | manual | 1d | 2023-10-10 | 2023-10-10 |  | start no earlier than 2023-10-10 |
| 682 | 1.2.5.3.4.1.16.20 | Progress meetings (with each WP) 20 | manual | 1d | 2023-11-14 | 2023-11-14 |  | start no earlier than 2023-11-14 |
| 683 | 1.2.5.3.4.1.16.21 | Progress meetings (with each WP) 21 | manual | 1d | 2023-12-12 | 2023-12-12 |  | start no earlier than 2023-12-12 |
| 684 | 1.2.5.3.4.1.16.22 | Progress meetings (with each WP) 22 | manual | 1d | 2024-01-09 | 2024-01-09 |  | start no earlier than 2024-01-09 |
| 685 | 1.2.5.3.4.1.16.23 | Progress meetings (with each WP) 23 | manual | 1d | 2024-02-13 | 2024-02-13 |  | start no earlier than 2024-02-13 |
| 686 | 1.2.5.3.4.1.16.24 | Progress meetings (with each WP) 24 | manual | 1d | 2024-03-12 | 2024-03-12 |  | start no earlier than 2024-03-12 |
| 687 | 1.2.5.3.4.1.16.25 | Progress meetings (with each WP) 25 | manual | 1d | 2024-04-09 | 2024-04-09 |  | start no earlier than 2024-04-09 |
| 688 | 1.2.5.3.4.1.16.26 | Progress meetings (with each WP) 26 | manual | 1d | 2024-05-14 | 2024-05-14 |  | start no earlier than 2024-05-14 |
| 689 | 1.2.5.3.4.1.16.27 | Progress meetings (with each WP) 27 | manual | 1d | 2024-06-11 | 2024-06-11 |  | start no earlier than 2024-06-11 |
| 690 | 1.2.5.3.4.1.16.28 | Progress meetings (with each WP) 28 | manual | 1d | 2024-07-09 | 2024-07-09 |  | start no earlier than 2024-07-09 |
| 691 | 1.2.5.3.4.1.16.29 | Progress meetings (with each WP) 29 | manual | 1d | 2024-08-13 | 2024-08-13 |  | start no earlier than 2024-08-13 |
| 692 | 1.2.5.3.4.1.16.30 | Progress meetings (with each WP) 30 | manual | 1d | 2024-09-10 | 2024-09-10 |  | start no earlier than 2024-09-10 |
| 693 | 1.2.5.3.4.1.16.31 | Progress meetings (with each WP) 31 | manual | 1d | 2024-10-08 | 2024-10-08 |  | start no earlier than 2024-10-08 |
| 694 | 1.2.5.3.4.1.16.32 | Progress meetings (with each WP) 32 | manual | 1d | 2024-11-12 | 2024-11-12 |  | start no earlier than 2024-11-12 |
| 695 | 1.2.5.3.4.1.16.33 | Progress meetings (with each WP) 33 | manual | 1d | 2024-12-10 | 2024-12-10 |  | start no earlier than 2024-12-10 |
| 696 | 1.2.5.3.4.1.16.34 | Progress meetings (with each WP) 34 | manual | 1d | 2025-01-14 | 2025-01-14 |  | start no earlier than 2025-01-14 |
| 697 | 1.2.5.3.4.1.16.35 | Progress meetings (with each WP) 35 | manual | 1d | 2025-02-11 | 2025-02-11 |  | start no earlier than 2025-02-11 |
| 698 | 1.2.5.3.4.1.16.36 | Progress meetings (with each WP) 36 | manual | 1d | 2025-03-11 | 2025-03-11 |  | start no earlier than 2025-03-11 |
| 699 | 1.2.5.3.4.1.16.37 | Progress meetings (with each WP) 37 | manual | 1d | 2025-04-08 | 2025-04-08 |  | start no earlier than 2025-04-08 |
| 700 | 1.2.5.3.4.1.16.38 | Progress meetings (with each WP) 38 | manual | 1d | 2025-05-13 | 2025-05-13 |  | start no earlier than 2025-05-13 |
| 701 | 1.2.5.3.4.1.16.39 | Progress meetings (with each WP) 39 | manual | 1d | 2025-06-10 | 2025-06-10 |  | start no earlier than 2025-06-10 |
| 702 | 1.2.5.3.4.1.16.40 | Progress meetings (with each WP) 40 | manual | 1d | 2025-07-08 | 2025-07-08 |  | start no earlier than 2025-07-08 |
| 703 | 1.2.5.3.4.1.16.41 | Progress meetings (with each WP) 41 | manual | 1d | 2025-08-12 | 2025-08-12 |  | start no earlier than 2025-08-12 |
| 704 | 1.2.5.3.4.1.16.42 | Progress meetings (with each WP) 42 | manual | 1d | 2025-09-09 | 2025-09-09 |  | start no earlier than 2025-09-09 |
| 705 | 1.2.5.3.4.1.16.43 | Progress meetings (with each WP) 43 | manual | 1d | 2025-10-14 | 2025-10-14 |  | start no earlier than 2025-10-14 |
| 706 | 1.2.5.3.4.1.16.44 | Progress meetings (with each WP) 44 | manual | 1d | 2025-11-11 | 2025-11-11 |  | start no earlier than 2025-11-11 |
| 707 | 1.2.5.3.4.1.16.45 | Progress meetings (with each WP) 45 | manual | 1d | 2025-12-09 | 2025-12-09 |  | start no earlier than 2025-12-09 |
| 708 | 1.2.5.3.4.1.16.46 | Progress meetings (with each WP) 46 | manual | 1d | 2026-01-13 | 2026-01-13 |  | start no earlier than 2026-01-13 |
| 709 | 1.2.5.3.4.1.16.47 | Progress meetings (with each WP) 47 | manual | 1d | 2026-02-10 | 2026-02-10 |  | start no earlier than 2026-02-10 |
| 710 | 1.2.5.3.4.1.16.48 | Progress meetings (with each WP) 48 | manual | 1d | 2026-03-10 | 2026-03-10 |  | start no earlier than 2026-03-10 |
| 711 | 1.2.5.3.4.1.16.49 | Progress meetings (with each WP) 49 | manual | 1d | 2026-04-14 | 2026-04-14 |  | start no earlier than 2026-04-14 |
| 712 | 1.2.5.3.4.1.16.50 | Progress meetings (with each WP) 50 | manual | 1d | 2026-05-12 | 2026-05-12 |  | start no earlier than 2026-05-12 |
| 713 | 1.2.5.3.4.1.16.51 | Progress meetings (with each WP) 51 | manual | 1d | 2026-06-09 | 2026-06-09 |  | start no earlier than 2026-06-09 |
| 714 | 1.2.5.3.4.1.16.52 | Progress meetings (with each WP) 52 | manual | 1d | 2026-07-14 | 2026-07-14 |  | start no earlier than 2026-07-14 |

| ID | WBS | Task | Type | Duration | Start | Finish | Total slack | Constraint |
| --- | --- | --- | --- | --- | --- | --- | --- | --- |
| 715 | 1.2.5.3.4.1.16.53 | Progress meetings (with each WP) 53 | manual | 1d | 2026-08-11 | 2026-08-11 |  | start no earlier than 2026-08-11 |
| 716 | 1.2.5.3.4.1.16.54 | Progress meetings (with each WP) 54 | manual | 1d | 2026-09-08 | 2026-09-08 |  | start no earlier than 2026-09-08 |
| 717 | 1.2.5.3.4.1.16.55 | Progress meetings (with each WP) 55 | manual | 1d | 2026-10-13 | 2026-10-13 |  | start no earlier than 2026-10-13 |
| 718 | 1.2.5.3.4.1.16.56 | Progress meetings (with each WP) 56 | manual | 1d | 2026-11-10 | 2026-11-10 |  | start no earlier than 2026-11-10 |
| 719 | 1.2.5.3.4.1.16.57 | Progress meetings (with each WP) 57 | manual | 1d | 2026-12-08 | 2026-12-08 |  | start no earlier than 2026-12-08 |
| 720 | 1.2.5.3.4.1.16.58 | Progress meetings (with each WP) 58 | manual | 1d | 2027-01-12 | 2027-01-12 |  | start no earlier than 2027-01-12 |
| 721 | 1.2.5.3.4.1.16.59 | Progress meetings (with each WP) 59 | manual | 1d | 2027-02-09 | 2027-02-09 |  | start no earlier than 2027-02-09 |
| 722 | 1.2.5.3.4.1.16.60 | Progress meetings (with each WP) 60 | manual | 1d | 2027-03-09 | 2027-03-09 |  | start no earlier than 2027-03-09 |
| 723 | 1.2.6 | **WP2 Source** |  | 1314d | 2022-04-01 | 2027-04-14 | 0d |  |
| 724 | 1.2.6.1 | **Milestones** |  | 782d | 2024-03-31 | 2027-03-31 | 0d |  |
| 725 | 1.2.6.1.1 | MS1 (Baseline sims - Lanc WP2) | milestone, manual | 0d | 2024-03-31 | 2024-03-31 |  |  |
| 726 | 1.2.6.1.2 | MS2 (WP2) | milestone, manual | 0d | 2024-03-31 | 2024-03-31 |  |  |
| 727 | 1.2.6.1.3 | MS3 (WP2) | milestone, manual | 0d | 2025-03-31 | 2025-03-31 |  |  |
| 728 | 1.2.6.1.4 | MS4 (WP2) | milestone, manual | 0d | 2025-09-30 | 2025-09-30 |  |  |
| 729 | 1.2.6.1.5 | MS5 (WP2) | milestone, manual | 0d | 2027-03-31 | 2027-03-31 |  |  |
| 730 | 1.2.6.1.6 | MS6 (WP2) | milestone, manual | 0d | 2027-03-31 | 2027-03-31 |  |  |
| 731 | 1.2.6.2 | **Tasks** |  | 1304d | 2022-04-01 | 2027-03-31 | 0d |  |
| 732 | 1.2.6.2.1 | Task 1 for MS1 (Basekine sims - Lanc) | manual | 522d | 2022-04-01 | 2024-03-31 |  |  |
| 733 | 1.2.6.2.2 | Task 2 for MS2 (Diagnostic package - Strath - SCAPA/ ICL - Zhi) | manual | 522d | 2022-04-01 | 2024-03-31 |  |  |
| 734 | 1.2.6.2.3 | Task 3 for MS3 ( Baseline SCAPA expt @1 Hz & PIC benchmarking - Strath- SCAPA / Lanc) | manual | 587d | 2023-01-01 | 2025-03-31 |  |  |
| 735 | 1.2.6.2.4 | Task 4 for MS4 (advanced targetry/stabilization/debris study @10 Hz - ICL - Zhi/ICL-cerberus/QUB/ Lanc) | manual | 913d | 2022-04-01 | 2025-09-30 |  |  |
| 736 | 1.2.6.2.5 | Task 5 for MS5 (Complete design source, integrate with capture - Strath- SCApA/ ICL - Zhi/ICL - Cerberus/ Lanc) | manual | 652d | 2024-10-01 | 2027-03-31 |  |  |
| 737 | 1.2.6.2.6 | Task 6 for MS6 (Repetitive operation @5Hz and full spec - Strath- SCAPA/all) | manual | 479d | 2025-04-01 | 2027-01-29 |  |  |
| 738 | 1.2.6.3 | **Reporting** |  | 1185d | 2022-09-29 | 2027-04-14 | 0d |  |
| 739 | 1.2.6.3.1 | Deliverable 1 | manual | 10d | 2022-09-29 | 2022-10-12 |  |  |
| 740 | 1.2.6.3.2 | Deliverable 2 | manual | 9d | 2023-04-03 | 2023-04-13 |  |  |
| 741 | 1.2.6.3.3 | Deliverable 3 | manual | 10d | 2023-10-02 | 2023-10-13 |  |  |
| 742 | 1.2.6.3.4 | Deliverable 4 | manual | 9d | 2024-04-01 | 2024-04-11 |  |  |
| 743 | 1.2.6.3.5 | Deliverable 5 | manual | 10d | 2024-09-23 | 2024-10-04 |  |  |
| 744 | 1.2.6.3.6 | Deliverable 6 | manual | 10d | 2025-04-01 | 2025-04-14 |  |  |
| 745 | 1.2.6.3.7 | Deliverable 7 | manual | 10d | 2025-10-02 | 2025-10-15 |  |  |
| 746 | 1.2.6.3.8 | Deliverable 8 | manual | 10d | 2026-04-01 | 2026-04-14 |  |  |
| 747 | 1.2.6.3.9 | Deliverable 9 | manual | 10d | 2026-10-02 | 2026-10-15 |  |  |
| 748 | 1.2.6.3.10 | Deliverable 10 | manual | 10d | 2027-04-01 | 2027-04-14 |  |  |

| ID | WBS | Task | Type | Duration | Start | Finish | Total slack |
| --- | --- | --- | --- | --- | --- | --- | --- |
| 749 | 1.2.7 | **WP3 Capture** |  | 1314d? | 2022-04-01 | 2027-04-14 |  |
| 750 | 1.2.7.1 | **Task 1** |  | 1304d? | 2022-04-01 | 2027-03-31 |  |
| 751 | 1.2.7.1.1 | Order & install low voltage plasma hardware | manual | 65d | 2022-04-01 | 2022-06-30 |  |
| 752 | 1.2.7.1.2 | Investigate low voltage with existing apparatus | manual | 131d | 2022-04-01 | 2022-09-30 |  |
| 753 | 1.2.7.1.3 | Order & install medium voltage hardware in existing apparatus | manual | 182d | 2022-04-01 | 2022-12-10 |  |
| 754 | 1.2.7.1.4 | Study medium voltage plasma in existing apparatus | manual | 262d | 2022-10-01 | 2023-09-30 |  |
| 755 | 1.2.7.1.5 | PIC modelling validation | manual | 197d | 2022-04-01 | 2022-12-31 |  |
| 756 | 1.2.7.1.6 | PIC modelling guidance | manual | 1174d | 2022-10-01 | 2027-03-31 |  |
| 757 | 1.2.7.2 | **Task 2** |  | 1304d | 2022-04-01 | 2027-03-31 |  |
| 758 | 1.2.7.2.1 | Order and assmeble high voltage plasma hardware | manual | 326d | 2022-04-01 | 2023-06-30 |  |
| 759 | 1.2.7.2.2 | commission high voltage plasma apparatus | manual | 132d | 2023-07-01 | 2023-12-31 |  |
| 760 | 1.2.7.2.3 | study high voltage plasma | manual | 587d | 2024-01-01 | 2026-03-31 |  |
| 761 | 1.2.7.2.4 | Interface & test testbench with test source | manual | 261d | 2026-04-01 | 2027-03-31 |  |
| 762 | 1.2.7.2.5 | Finalise design for usable Gabor lens | manual | 64d | 2027-01-01 | 2027-03-31 |  |
| 763 | 1.2.7.3 | **Risk Mitigation** |  | 1314d | 2022-04-01 | 2027-04-14 |  |
| 764 | 1.2.7.3.1 | install existing Magnet until new magnet is available | manual | 67d | 2023-07-01 | 2023-09-30 |  |
| 765 | 1.2.7.3.2 | obtain custom electronics | manual | 66d | 2024-10-01 | 2024-12-31 |  |
| 766 | 1.2.7.4 | **Reporting** |  | 1185d | 2022-09-29 | 2027-04-14 | 0d |
| 767 | 1.2.7.4.1 | Deliverable 1 | manual | 10d | 2022-09-29 | 2022-10-12 |  |
| 768 | 1.2.7.4.2 | Deliverable 2 | manual | 9d | 2023-04-03 | 2023-04-13 |  |
| 769 | 1.2.7.4.3 | Deliverable 3 | manual | 10d | 2023-10-02 | 2023-10-13 |  |
| 770 | 1.2.7.4.4 | Deliverable 4 | manual | 9d | 2024-04-01 | 2024-04-11 |  |
| 771 | 1.2.7.4.5 | Deliverable 5 | manual | 10d | 2024-09-23 | 2024-10-04 |  |
| 772 | 1.2.7.4.6 | Deliverable 6 | manual | 10d | 2025-04-01 | 2025-04-14 |  |
| 773 | 1.2.7.4.7 | Deliverable 7 | manual | 10d | 2025-10-02 | 2025-10-15 |  |
| 774 | 1.2.7.4.8 | Deliverable 8 | manual | 10d | 2026-04-01 | 2026-04-14 |  |
| 775 | 1.2.7.4.9 | Deliverable 9 | manual | 10d | 2026-10-02 | 2026-10-15 |  |
| 776 | 1.2.7.4.10 | Deliverable 10 | manual | 10d | 2027-04-01 | 2027-04-14 |  |

| ID | WBS | Task | Type | Duration | Start | Finish | Total slack |
| --- | --- | --- | --- | --- | --- | --- | --- |
| 777 | 1.2.8 | **WP4 Ion-acoustic** |  | 1314d? | 2022-04-01 | 2027-04-14 |  |
| 778 | 1.2.8.1 | **Preliminary activity (PA)** |  | 782d | 2022-04-01 | 2025-03-31 |  |
| 779 | 1.2.8.1.1 | task 1 - review- current state of the art : ionacoustics.proton dosimetry | manual | 65d | 2022-04-01 | 2022-06-30 |  |
| 780 | 1.2.8.1.2 | Task 2 development of GEANT 4 Monte Carlo part of the forward model | manual | 717d | 2022-07-01 | 2025-03-31 |  |
| 781 | 1.2.8.1.3 | Task 3 development of k-Wave forward acoustic model | manual | 392d | 2022-10-01 | 2024-03-31 |  |
| 782 | 1.2.8.1.4 | task 5 assembly of apparatus for validation of models and approach | manual | 412d | 2022-04-01 | 2023-10-30 |  |
| 783 | 1.2.8.1.5 | Task 6 forward model validation experiments | manual | 262d | 2023-10-01 | 2024-09-30 |  |
| 784 | 1.2.8.2 | **Preconstruction programme** |  | 793d | 2024-04-01 | 2027-04-14 |  |
| 785 | 1.2.8.2.1 | Task 4. implementation, simulation evaluation and development of inverse dose-map reconstruction software | manual | 589d | 2023-10-01 | 2025-12-31 |  |
| 786 | 1.2.8.2.2 | Task 7 assembly and integration of dosimeters for use in radiobiological studies | manual | 718d | 2023-10-01 | 2026-06-30 |  |
| 787 | 1.2.8.2.3 | Task 8 acoustically compatible biological sample holders for high -throughput radiobiological studies | manual | 1044d | 2023-04-01 | 2027-03-31 |  |
| 788 | 1.2.8.2.4 | Task 9 Final experiments with LhARA | manual | 457d | 2025-06-01 | 2027-03-01 |  |
| 789 | 1.2.8.2.5 | **Reporting** |  | 1185d | 2022-09-29 | 2027-04-14 | 0d |
| 790 | 1.2.8.2.5.1 | Deliverable 1 | manual | 10d | 2022-09-29 | 2022-10-12 |  |
| 791 | 1.2.8.2.5.2 | Deliverable 2 | manual | 9d | 2023-04-03 | 2023-04-13 |  |
| 792 | 1.2.8.2.5.3 | Deliverable 3 | manual | 10d | 2023-10-02 | 2023-10-13 |  |
| 793 | 1.2.8.2.5.4 | Deliverable 4 | manual | 9d | 2024-04-01 | 2024-04-11 |  |
| 794 | 1.2.8.2.5.5 | Deliverable 5 | manual | 10d | 2024-09-23 | 2024-10-04 |  |
| 795 | 1.2.8.2.5.6 | Deliverable 6 | manual | 10d | 2025-04-01 | 2025-04-14 |  |
| 796 | 1.2.8.2.5.7 | Deliverable 7 | manual | 10d | 2025-10-02 | 2025-10-15 |  |
| 797 | 1.2.8.2.5.8 | Deliverable 8 | manual | 10d | 2026-04-01 | 2026-04-14 |  |
| 798 | 1.2.8.2.5.9 | Deliverable 9 | manual | 10d | 2026-10-02 | 2026-10-15 |  |
| 799 | 1.2.8.2.5.10 | Deliverable 10 | manual | 10d | 2027-04-01 | 2027-04-14 |  |
| 800 | 1.2.8.3 | **Reporting** |  | 1185d | 2022-09-29 | 2027-04-14 | 0d |
| 801 | 1.2.8.3.1 | Deliverable 1 | manual | 10d | 2022-09-29 | 2022-10-12 |  |
| 802 | 1.2.8.3.2 | Deliverable 2 | manual | 9d | 2023-04-03 | 2023-04-13 |  |
| 803 | 1.2.8.3.3 | Deliverable 3 | manual | 10d | 2023-10-02 | 2023-10-13 |  |
| 804 | 1.2.8.3.4 | Deliverable 4 | manual | 9d | 2024-04-01 | 2024-04-11 |  |
| 805 | 1.2.8.3.5 | Deliverable 5 | manual | 10d | 2024-09-23 | 2024-10-04 |  |
| 806 | 1.2.8.3.6 | Deliverable 6 | manual | 10d | 2025-04-01 | 2025-04-14 |  |
| 807 | 1.2.8.3.7 | Deliverable 7 | manual | 10d | 2025-10-02 | 2025-10-15 |  |
| 808 | 1.2.8.3.8 | Deliverable 8 | manual | 10d | 2026-04-01 | 2026-04-14 |  |
| 809 | 1.2.8.3.9 | Deliverable 9 | manual | 10d | 2026-10-02 | 2026-10-15 |  |
| 810 | 1.2.8.3.10 | Deliverable 10 | manual | 10d | 2027-04-01 | 2027-04-14 |  |
| 811 | 1.2.8.4 | Facility construction | manual | 457d | 2025-07-01 | 2027-03-31 |  |
| 812 | 1.2.8.5 | facility exploitation | manual | 1d? | 2022-04-01 | 2022-04-01 |  |
| 813 | 1.2.9 | WP5 Vertical Beamline | manual | 1304d | 2022-04-01 | 2027-03-31 |  |
| 814 | 1.2.10 | WP6 System design | manual | 1304d | 2022-04-01 | 2027-03-31 |  |
